# Sites - Contract Strategy Schedule

Schedule from MS Project, 2022-01-01 to 2034-09-28.

## Calendars

- Standard: Mon-Fri 08:00-12:00, 13:00-17:00; Sat-Sun off.

## Schedule

| ID | WBS | Task | Type | Duration | Start | Finish | Predecessors | Total slack | Free slack | Constraint |
| --- | --- | --- | --- | --- | --- | --- | --- | --- | --- | --- |
| 2 | 1 | **Environmental Permitting** |  | 2144d | 2023-01-30 | 2031-04-17 |  | 284d |  |  |
| 3 | 1.1 | CEQA Certification | milestone | 0d | 2023-01-30 | 2023-01-30 |  | 344d | 0d | start no earlier than 2023-01-30 |
| 4 | 1.2 | Obtain Water Right | milestone | 0d | 2024-03-01 | 2024-03-01 |  | 0d |  | start no earlier than 2024-03-01 |
| 5 | 1.3 | Interim Financing | milestone | 0d | 2024-08-15 | 2024-08-15 | 4FS+6mo | 0d |  |  |
| 6 | 1.4 | General Permits for ESA; 404/401; Cultural Resources |  | 12mo | 2023-01-30 | 2023-12-29 | 3 | 464d | 0d |  |
| 7 | 1.5 | Property Access for Bio/CR Field Surveys Res Package |  | 12mo | 2023-01-30 | 2023-12-29 | 3 | 464d | 0d |  |
| 8 | 1.6 | Enviro Surveys Res Package |  | 24mo | 2024-01-01 | 2025-10-31 | 7, 6 | 464d | 0d |  |
| 9 | 1.7 | Regulatory Reviews Res Package |  | 9mo | 2025-11-03 | 2026-07-10 | 8 | 464d | 0d |  |
| 10 | 1.8 | Mitigation for Res Package |  | 18mo | 2026-07-13 | 2027-11-26 | 9 | 464d | 0d |  |
| 11 | 1.9 | Property Access for Bio/CR Field Surveys Conveyance |  | 12mo | 2023-01-30 | 2023-12-29 | 3 | 464d | 0d |  |
| 12 | 1.10 | Enviro Surveys Conveyance |  | 24mo | 2024-01-01 | 2025-10-31 | 11, 6 | 464d | 0d |  |
| 13 | 1.11 | Regulatory Reviews for Conveyance |  | 9mo | 2025-11-03 | 2026-07-10 | 12 | 464d | 0d |  |
| 14 | 1.12 | Mitigation for Conveyance |  | 12mo | 2026-07-13 | 2027-06-11 | 13 | 464d | 0d |  |
| 15 | 1.13 | Property Access for Enviro Surveys for Reservoir Clearing |  | 18mo | 2023-01-30 | 2024-06-14 | 3 | 344d | 0d |  |
| 16 | 1.14 | Enviro Surveys for Reservoir Clearing |  | 24mo | 2024-06-17 | 2026-04-17 | 15, 6 | 344d | 0d |  |
| 17 | 1.15 | Regulatory Reviews for Reservoir Clearing |  | 9mo | 2026-04-20 | 2026-12-25 | 16 | 344d | 0d |  |
| 18 | 1.16 | Mitigation for Reservoir Clearing |  | 12mo | 2026-12-28 | 2027-11-26 | 17 | 344d |  |  |
| 19 | 1.17 | Property Access for Dunnigan Pipeline upstream segment Enviro Surveys |  | 12mo | 2023-01-30 | 2023-12-29 | 3 | 1604d | 0d |  |
| 20 | 1.18 | Enviro Surveys for Dunnigan Pipeline upstream segment |  | 12mo | 2024-01-01 | 2024-11-29 | 19, 6 | 1604d | 0d |  |
| 21 | 1.19 | Regulatory Reviews for Dunnigan Pipeline upstream segement |  | 9mo | 2024-12-02 | 2025-08-08 | 20 | 1604d | 1244d |  |
| 22 | 1.20 | Property Access for Dunnigan Pipeline downstream segment Enviro Surveys |  | 12mo | 2027-11-05 | 2028-10-05 | 3, 129 | 360d | 0d |  |
| 23 | 1.21 | Enviro Surveys for Dunnigan Pipeline downstream segment |  | 12mo | 2028-10-06 | 2029-09-06 | 22 | 360d | 0d |  |
| 24 | 1.22 | Regulatory Reviews for Dunnigan Pipeline downstream segment |  | 9mo | 2029-09-07 | 2030-05-16 | 23 | 360d | 0d |  |
| 25 | 1.23 | Mitigation for Dunnigan Pipeline (both segments) |  | 12mo | 2030-05-17 | 2031-04-17 | 21, 24 | 360d | 167d |  |

| ID | WBS | Task | Type | Duration | Start | Finish | Predecessors | Total slack | Free slack | Constraint |
| --- | --- | --- | --- | --- | --- | --- | --- | --- | --- | --- |
| 26 | 2 | **Reservoir Package** |  | 2860d | 2022-01-03 | 2032-12-17 |  | 0d |  |  |
| 27 | 2.1 | **30% Design** |  | 600d | 2022-01-03 | 2024-04-19 |  | 0d |  |  |
| 28 | 2.1.1 | Initiate and progress 30% Design | manual | 18mo | 2022-01-03 | 2023-05-19 |  |  |  |  |
| 29 | 2.1.2 | Access rights for dams and bridge geotech |  | 7mo | 2022-06-20 | 2022-12-30 | 28SS+6mo | 664d | 0d |  |
| 30 | 2.1.3 | Geotech exploration |  | 12mo | 2023-01-02 | 2023-12-01 | 29 | 664d | 0d |  |
| 31 | 2.1.4 | Complete 30% design and submit for DSOD review |  | 2mo | 2023-12-04 | 2024-01-26 | 30, 28 | 664d | 0d |  |
| 32 | 2.1.5 | DSOD Review Res Package 30% (jurisdictional elements only) |  | 3mo | 2024-01-29 | 2024-04-19 | 31 | 664d | 0d |  |
| 33 | 2.2 | **60% Design** |  | 240d | 2024-01-29 | 2024-12-27 |  | 664d |  |  |
| 34 | 2.2.1 | Initiate and progress 60% Design |  | 6mo | 2024-01-29 | 2024-07-12 | 31 | 684d | 20d |  |
| 35 | 2.2.2 | Address DSOD Comments on 30% design |  | 6mo | 2024-04-22 | 2024-10-04 | 32 | 664d | 0d |  |
| 36 | 2.2.3 | 60% Geotech exploration |  | 6mo | 2024-02-26 | 2024-08-09 | 35FF-2mo, 34SS | 664d | 0d |  |
| 37 | 2.2.4 | Complete 60% Design and Submit to DSOD for Review |  | 2mo | 2024-08-12 | 2024-10-04 | 36 | 664d | 0d |  |
| 38 | 2.2.5 | DSOD Review Res Package 60% (jurisdictional elements only) |  | 3mo | 2024-10-07 | 2024-12-27 | 37 | 664d | 0d |  |
| 39 | 2.3 | **90% Design** |  | 280d | 2024-10-07 | 2025-10-31 |  | 664d |  |  |
| 40 | 2.3.1 | Initiate and progress 90% Design |  | 6mo | 2024-10-07 | 2025-03-21 | 37 | 724d | 60d |  |
| 41 | 2.3.2 | Address DSOD Comments on 60% Design |  | 6mo | 2024-12-30 | 2025-06-13 | 38 | 664d | 0d |  |
| 42 | 2.3.3 | Complete 90% Design and submit to DSOD (jurisdictional elements only) |  | 2mo | 2025-06-16 | 2025-08-08 | 41, 40 | 664d | 0d |  |
| 43 | 2.3.4 | DSOD Review 90% Design |  | 3mo | 2025-08-11 | 2025-10-31 | 42 | 664d | 0d |  |
| 44 | 2.4 | **100% Design** |  | 280d | 2025-08-11 | 2026-09-04 |  | 664d |  |  |
| 45 | 2.4.1 | Initiate and progress 100% Design |  | 6mo | 2025-08-11 | 2026-01-23 | 42 | 724d | 60d |  |
| 46 | 2.4.2 | Address DSOD Comments on 90% Design |  | 6mo | 2025-11-03 | 2026-04-17 | 43 | 664d | 0d |  |
| 47 | 2.4.3 | Complete 100% Design and submit to DSOD (jurisdictional elements only) |  | 2mo | 2026-04-20 | 2026-06-12 | 46, 45 | 664d | 0d |  |
| 48 | 2.4.4 | DSOD approves 100% Design |  | 3mo | 2026-06-15 | 2026-09-04 | 47 | 664d | 0d |  |
| 49 | 2.5 | **Reservoir Package Construction** |  | 2176d | 2024-08-16 | 2032-12-17 |  | 464d |  |  |
| 50 | 2.5.1 | Bidding and Contract Execution for Reservoir Package |  | 6mo | 2026-09-07 | 2027-02-19 | 48 | 664d | 200d |  |
| 51 | 2.5.2 | Obtain Property Rights for Reservoir Package Construction |  | 24mo | 2024-08-16 | 2026-06-18 | 5 | 840d | 376d | start no earlier than 2023-01-31 |
| 52 | 2.5.3 | Reservoir Package Mobilization |  | 3mo | 2027-11-29 | 2028-02-18 | 51, 14, 50, 10 | 464d | 0d |  |
| 53 | 2.5.4 | Reservoir Package Construction |  | 60mo | 2028-02-21 | 2032-09-24 | 52 | 464d | 0d |  |
| 54 | 2.5.5 | DSOD Approves Dams Construction |  | 3mo | 2032-09-27 | 2032-12-17 | 53 | 464d |  |  |

| ID | WBS | Task | Type | Duration | Start | Finish | Predecessors | Total slack | Free slack | Constraint |
| --- | --- | --- | --- | --- | --- | --- | --- | --- | --- | --- |
| 55 | 3 | **I/O** |  | 1944d | 2022-01-03 | 2029-06-14 |  | 0d |  |  |
| 56 | 3.1 | **30% Design** |  | 540d | 2022-01-03 | 2024-01-26 |  | 0d |  |  |
| 57 | 3.1.1 | Initiate and progress 30% Design | manual | 18mo | 2022-01-03 | 2023-05-19 |  |  |  |  |
| 58 | 3.1.2 | Access rights for I/O geotech explorations |  | 7mo | 2022-06-20 | 2022-12-30 | 57SS+6mo | 2464d | 0d |  |
| 59 | 3.1.3 | 30% Geotech exploration |  | 12mo | 2023-01-02 | 2023-12-01 | 58 | 2464d | 0d |  |
| 60 | 3.1.4 | Complete 30% design |  | 2mo | 2023-12-04 | 2024-01-26 | 57, 59 | 2464d | 0d |  |
| 61 | 3.2 | **60% Design** |  | 760d | 2022-01-03 | 2024-11-29 |  | 2564d |  |  |
| 62 | 3.2.1 | Initiate and progress 60% Design |  | 6mo | 2024-01-29 | 2024-07-12 | 60 | 2464d | 0d |  |
| 63 | 3.2.2 | Address DSOD Comments on 30% design |  | 6mo | 2022-01-03 | 2022-06-17 |  | 3004d | 540d |  |
| 64 | 3.2.3 | 60% Geotech exploration |  | 6mo | 2024-01-29 | 2024-07-12 | 62SS, 63FF-2mo | 2464d | 0d |  |
| 65 | 3.2.4 | Complete 60% Design and submit to DSOD for review |  | 2mo | 2024-07-15 | 2024-09-06 | 63, 64, 62 | 2464d | 0d |  |
| 66 | 3.2.5 | DSOD review of 60% |  | 3mo | 2024-09-09 | 2024-11-29 | 65 | 2564d |  |  |
| 67 | 3.3 | **90% Design** |  | 820d | 2022-01-03 | 2025-02-21 |  | 2504d |  |  |
| 68 | 3.3.1 | Initiate and progress 60% Design |  | 6mo | 2024-09-09 | 2025-02-21 | 65 | 2504d |  |  |
| 69 | 3.3.2 | Address DSOD Comments on 60% Design |  | 6mo | 2022-01-03 | 2022-06-17 |  | 3044d | 580d |  |
| 70 | 3.3.3 | Complete 90% Design |  | 2mo | 2024-09-09 | 2024-11-01 | 69, 65 | 2464d | 0d |  |
| 71 | 3.4 | **100% Design** |  | 860d | 2022-01-03 | 2025-04-18 |  | 1524d |  |  |
| 72 | 3.4.1 | Initiate and progress 100% Design |  | 6mo | 2024-11-04 | 2025-04-18 | 70 | 2464d |  |  |
| 73 | 3.4.2 | Address DSOD Comments on 90% Design |  | 6mo | 2022-01-03 | 2022-06-17 |  | 1524d | 0d |  |
| 74 | 3.4.3 | Complete 100% Design |  | 2mo | 2022-06-20 | 2022-08-12 | 73 | 1584d | 0d |  |
| 75 | 3.5 | TBM Ordered |  | 12mo | 2022-06-20 | 2023-05-19 | 73 | 1524d | 864d |  |
| 76 | 3.6 | **I/O Construction** |  | 1784d | 2022-08-15 | 2029-06-14 |  | 660d |  |  |
| 77 | 3.6.1 | Bidding and Contract Execution for I/O Package |  | 4mo | 2022-08-15 | 2022-12-02 | 74 | 1584d | 924d |  |
| 78 | 3.6.2 | Obtain Property Rights for I/O Construction |  | 24mo | 2024-08-16 | 2026-06-18 | 5 | 660d | 0d | start no earlier than 2023-01-31 |
| 79 | 3.6.3 | I/O Mobilization |  | 3mo | 2026-06-19 | 2026-09-10 | 78, 77 | 660d | 0d |  |
| 80 | 3.6.4 | I/O Construction |  | 36mo | 2026-09-11 | 2029-06-14 | 79, 78, 75 | 660d |  |  |

Notes:
- 78: listed as 24 months (condemnation may be required for 1 landowner). Kevin will know more info in the next 6 months

| ID | WBS | Task | Type | Duration | Start | Finish | Predecessors | Total slack | Free slack | Constraint |
| --- | --- | --- | --- | --- | --- | --- | --- | --- | --- | --- |
| 81 | 4 | **"Conveyance" Package (including I/O)** |  | 2140d | 2022-01-03 | 2030-03-15 |  | 0d |  |  |
| 82 | 4.1 | CA ISO Review of Electrical System Study Task> |  | 24mo | 2022-12-05 | 2024-10-04 | 84 | 2604d |  |  |
| 83 | 4.2 | **30% Design** |  | 739d | 2022-01-03 | 2024-10-31 |  | 0d |  |  |
| 84 | 4.2.1 | Initiate and progress 30% Design | manual | 12mo | 2022-01-03 | 2022-12-02 |  |  |  |  |
| 85 | 4.2.2 | Access rights for conveyance geotech explorations |  | 7mo | 2022-12-02 | 2023-06-15 | 87 | 585d | 0d |  |
| 86 | 4.2.3 | Geotech exploration for 30% |  | 12mo | 2023-06-16 | 2024-05-16 | 85 | 585d | 0d |  |
| 87 | 4.2.4 | Select TRR alternative | milestone | 0d | 2022-12-02 | 2022-12-02 |  | 585d | 0d | start no earlier than 2022-12-02 |
| 88 | 4.2.5 | Complete 30% design and submit to DSOD for review (jurisdictional elements only) |  | 3mo | 2024-05-17 | 2024-08-08 | 86, 84, 87 | 585d | 0d |  |
| 89 | 4.2.6 | DSOD review 30% Conveyance |  | 3mo | 2024-08-09 | 2024-10-31 | 88 | 585d | 0d |  |
| 90 | 4.3 | **60% Design** |  | 300d | 2024-08-09 | 2025-10-02 |  | 585d |  |  |
| 91 | 4.3.1 | Initiate and progress 60% Design |  | 6mo | 2024-08-09 | 2025-01-23 | 88 | 645d | 0d |  |
| 92 | 4.3.2 | Address DSOD comments on 30% (jurisdictional elements only) |  | 6mo | 2024-11-01 | 2025-04-17 | 89 | 585d | 0d |  |
| 93 | 4.3.3 | Geotech exploration for 60% design |  | 6mo | 2024-08-09 | 2025-01-23 | 91SS | 645d | 60d |  |
| 94 | 4.3.4 | Complete 60% design and submit to DSOD for review (jurisdictional elements only) |  | 3mo | 2025-04-18 | 2025-07-10 | 93, 91, 92 | 585d | 0d |  |
| 95 | 4.3.5 | DSOD review 60% conveyance design |  | 3mo | 2025-07-11 | 2025-10-02 | 94 | 585d | 0d |  |
| 96 | 4.4 | **90% Design** |  | 240d | 2025-07-11 | 2026-06-11 |  | 585d | 0d |  |
| 97 | 4.4.1 | Initiate 90% Design |  | 6mo | 2025-07-11 | 2025-12-25 | 94 | 705d |  |  |
| 98 | 4.4.2 | Address DSOD Comments on 60%, complete 90% design and submit 90% package for DSOD review |  | 6mo | 2025-10-03 | 2026-03-19 | 95 | 585d | 0d |  |
| 99 | 4.4.3 | DSOD review 90% conveyance design (jurisdictional elements only) |  | 3mo | 2026-03-20 | 2026-06-11 | 98 | 585d | 0d |  |
| 100 | 4.5 | **100% Design** |  | 200d | 2026-03-20 | 2026-12-24 |  | 2025d |  |  |
| 101 | 4.5.1 | Initiate 100% Design |  | 6mo | 2026-03-20 | 2026-09-03 | 98 | 2105d |  |  |
| 102 | 4.5.2 | Address DSOD comments on 90%, complete design and submit to DSOD for approval |  | 4mo | 2026-06-12 | 2026-10-01 | 99 | 2025d | 0d |  |
| 103 | 4.5.3 | DSOD approval of 100% design |  | 3mo | 2026-10-02 | 2026-12-24 | 102 | 2025d |  |  |
| 104 | 4.6 | **Conveyance Construction** |  | 1456d | 2024-08-16 | 2030-03-15 |  | 464d |  |  |
| 105 | 4.6.1 | Bidding and Contract Execution for Conveyance Package |  | 4mo | 2026-06-12 | 2026-10-01 | 96 | 585d | 0d |  |
| 106 | 4.6.2 | Obtain Property Rights for Conveyance Construction |  | 24mo | 2024-08-16 | 2026-06-18 | 5 | 660d | 75d | start no earlier than 2022-01-31 |
| 107 | 4.6.3 | Conveyance Mobilization |  | 3mo | 2026-10-02 | 2026-12-24 | 106, 105 | 585d | 121d |  |
| 108 | 4.6.4 | Conveyance Construction |  | 36mo | 2027-06-14 | 2030-03-15 | 107, 14 | 464d |  |  |

| ID | WBS | Task | Type | Duration | Start | Finish | Predecessors | Total slack | Free slack | Constraint |
| --- | --- | --- | --- | --- | --- | --- | --- | --- | --- | --- |
| 109 | 5 | **Reservoir Clearing/Demo** |  | 1200d | 2027-05-21 | 2031-12-25 |  | 0d |  |  |
| 110 | 5.1 | Obtain Property for Reservoir Clearing/Demo |  | 24mo | 2027-05-21 | 2029-03-22 | 5SS+36mo | 0d |  | start no earlier than 2023-01-31 |
| 111 | 5.2 | Reservoir Clearing/Demo |  | 24mo | 2029-03-23 | 2031-01-23 | 110, 18 | 240d |  |  |
| 112 | 5.3 | Cemetary Relocation |  | 36mo | 2029-03-23 | 2031-12-25 | 110, 18 | 0d |  |  |
| 113 | 6 | Reservoir Filling/Commissioning |  | 36mo | 2031-12-26 | 2034-09-28 | 108, 111, 112, 80 | 0d |  |  |
| 115 | 7 | Initiate Operations | milestone | 0d | 2034-09-28 | 2034-09-28 | 113, 141 | 0d |  |  |
| 117 | 8 | **Dunnigan Pipeline** |  | 3131d | 2022-01-01 | 2034-01-02 |  | 193d |  |  |
| 118 | 8.1 | **Upstream segment** |  | 2934d | 2022-01-01 | 2033-03-31 |  | 390d |  |  |
| 119 | 8.1.1 | **30% design upstream segment** |  | 2934d | 2022-01-01 | 2033-03-31 |  | 390d |  |  |
| 120 | 8.1.1.1 | Pause design on Dunnigan Pipeline? | milestone | 0d | 2022-01-01 | 2022-01-01 |  | 3324d |  |  |
| 121 | 8.1.1.2 | Determine if upstream segment should be upsized |  | 6mo | 2024-03-01 | 2024-08-15 | 4, 3 | 2640d |  | start no earlier than 2022-09-01 |
| 122 | 8.1.1.3 | Access rights for geotech exploration and survey |  | 6mo | 2023-01-04 | 2023-06-20 |  | 390d | 0d | start no earlier than 2023-01-04 |
| 123 | 8.1.1.4 | Survey and Geotech |  | 7.2mo | 2023-06-21 | 2033-03-31 | 122 | 390d |  |  |
| 124 | 8.1.1.5 | Complete 30% design of upstream segment |  | 4mo | 2022-01-03 | 2022-04-22 |  | 2364d | 0d |  |
| 125 | 8.1.2 | 60% design upstream segment |  | 6mo | 2022-04-25 | 2022-10-07 | 124 | 2364d | 0d |  |
| 126 | 8.1.3 | 90% design upstream segment |  | 4mo | 2022-10-10 | 2023-01-27 | 125 | 2364d | 2171d |  |
| 127 | 8.2 | **Downstream segment** |  | 1887d | 2024-03-01 | 2031-05-26 |  | 193d |  |  |
| 128 | 8.2.1 | **30% design downstream segment** |  | 1687d | 2024-03-01 | 2030-08-19 |  | 193d |  |  |
| 129 | 8.2.1.1 | Determine if downstream segment discharges to Colusa Basin Drain or Sac River |  | 48mo | 2024-03-01 | 2027-11-04 | 4, 3 | 193d | 0d |  |
| 130 | 8.2.1.2 | Access rights for geotech exploration and survey |  | 6mo | 2027-11-05 | 2028-04-20 | 129 | 193d | 0d | start no earlier than 2023-01-04 |
| 131 | 8.2.1.3 | Survey and Geotech |  | 9.2mo | 2028-04-21 | 2030-04-29 | 130 | 193d | 0d |  |
| 132 | 8.2.1.4 | Complete 30% design of downstream segment |  | 4mo | 2030-04-30 | 2030-08-19 | 131 | 193d | 0d |  |
| 133 | 8.2.2 | 60% design downstream segment |  | 6mo | 2030-08-20 | 2031-02-03 | 132 | 193d | 0d |  |
| 134 | 8.2.3 | 90% design downstream segment |  | 4mo | 2031-02-04 | 2031-05-26 | 133 | 193d | 0d |  |

| ID | WBS | Task | Type | Duration | Start | Finish | Predecessors | Total slack | Free slack |
| --- | --- | --- | --- | --- | --- | --- | --- | --- | --- |
| 135 | 8.3 | **Complete design and construction** |  | 2447d | 2024-08-16 | 2034-01-02 |  | 193d |  |
| 136 | 8.3.1 | Obtain Property rights for Dunnigan Pipeline construction |  | 12mo | 2024-08-16 | 2025-07-17 | 5 | 1860d | 1667d |
| 137 | 8.3.2 | Last date to combine upstream and downstream segments for construction | milestone | 0d | 2031-05-26 | 2031-05-26 | 134, 126 | 873d |  |
| 138 | 8.3.3 | 100% design for both segments |  | 3mo | 2031-05-27 | 2031-08-18 | 134, 126 | 193d | 0d |
| 139 | 8.3.4 | Bid and execute contract |  | 4mo | 2031-08-19 | 2031-12-08 | 138 | 193d | 0d |
| 140 | 8.3.5 | Dunnigan Pipeline Mobilization |  | 3mo | 2031-12-09 | 2032-03-01 | 139, 136, 25 | 193d | 0d |
| 141 | 8.3.6 | Dunnigan Pipeline Construction |  | 24mo | 2032-03-02 | 2034-01-02 | 140 | 193d |  |
