# Sites Reservoir Dams Construction - rev 6 11-09-20

Schedule from MS Project, 2022-01-03 to 2033-04-28.

## Calendars

- Standard: Mon-Fri 08:00-12:00, 13:00-17:00; Sat-Sun off.

## Schedule

| ID | WBS | Task | Type | Duration | Start | Finish | Predecessors | Total slack | Free slack | Constraint |
| --- | --- | --- | --- | --- | --- | --- | --- | --- | --- | --- |
| 1 | 1 | Start Task Order 3 - Preliminary Engineering | milestone | 0d | 2022-01-03 | 2022-01-03 |  | 2954d |  | start no earlier than 2022-01-03 |
| 2 | 2 | Determine Construction Packaging & Delivery Methods | manual | 149d | 2022-01-03 | 2022-07-28 |  |  |  |  |
| 3 | 3 | Real Estate Team Gain Access for Surveying & Geotech Investigation |  | 800d | 2022-01-03 | 2025-01-24 |  | 2154d |  | start no earlier than 2022-01-03 |
| 4 | 4 | Topographic Survey and Mapping |  | 181d | 2022-01-03 | 2022-09-12 |  | 2773d |  | start no earlier than 2022-01-03 |
| 5 | 5 | **Geotech Investigations** |  | 1263d | 2022-03-01 | 2026-12-31 |  | 0d |  |  |
| 6 | 5.1 | Phase 1 Geotech investigation for Preliminary (30%) Design |  | 741d | 2022-03-01 | 2024-12-31 |  | 0d |  | start no earlier than 2022-03-01 |
| 7 | 5.2 | Phase 2 Geotech Investigation for 60% Design |  | 261d | 2025-01-01 | 2025-12-31 | 6 | 0d |  |  |
| 8 | 5.3 | Phase 2 Geotech Investigation for Final Design |  | 261d | 2026-01-01 | 2026-12-31 | 7 | 0d |  |  |
| 9 | 6 | **CONSTRUCTION PACKAGE #1 - RESERVOIR FACILITIES** |  | 1652d | 2024-12-04 | 2031-04-03 |  | 540d |  |  |
| 10 | 6.1 | **Engineering** |  | 752d | 2024-12-04 | 2027-10-21 |  | 540d |  |  |
| 11 | 6.1.1 | Preliminary Engineering |  | 195d | 2024-12-04 | 2025-09-02 | 2, 6FS-20d | 540d | 0d |  |
| 12 | 6.1.2 | Final Engineering |  | 210d | 2027-01-01 | 2027-10-21 | 8, 11 | 1440d |  |  |
| 13 | 6.2 | **Administrative and General** |  | 210d | 2025-09-02 | 2026-06-23 |  | 540d |  |  |
| 14 | 6.2.1 | Contract Award | milestone | 0d | 2025-09-02 | 2025-09-02 | 2, 11 | 540d | 0d |  |
| 15 | 6.2.2 | Notice To Proceed |  | 60d | 2025-09-03 | 2025-11-25 | 14 | 540d | 0d |  |
| 16 | 6.2.3 | Early Submittals And Approvals |  | 90d | 2025-11-26 | 2026-03-31 | 15 | 540d | 0d |  |
| 17 | 6.2.4 | Mobilization |  | 60d | 2026-04-01 | 2026-06-23 | 16 | 540d | 0d |  |
| 18 | 6.3 | **Construction** |  | 1185d | 2026-05-13 | 2030-11-26 |  | 570d |  |  |
| 19 | 6.3.1 | **Roads, Bridges, Access, and Site Development** |  | 831d | 2026-05-13 | 2029-07-18 |  | 570d | 354d |  |
| 20 | 6.3.1.1 | Site Access and Staging Development |  | 100d | 2026-06-24 | 2026-11-10 | 17 | 540d | 0d |  |
| 21 | 6.3.1.2 | Northern Construction Access Roads |  | 284d | 2026-06-24 | 2027-07-26 | 17 | 626d | 0d |  |
| 22 | 6.3.1.3 | Southern Construction Access Roads |  | 274d | 2026-06-24 | 2027-07-12 | 17 | 722d | 0d |  |
| 23 | 6.3.1.4 | Sites Lodoga Road Realignment and Bridge |  | 680d | 2026-05-13 | 2028-12-19 | 17SS+30d | 1045d |  |  |
| 24 | 6.3.1.5 | Huffmaster Road Realignment |  | 801d | 2026-06-24 | 2029-07-18 | 17 | 894d |  |  |
| 25 | 6.3.1.6 | Reservoir Footprint Mitigation Actions |  | 500d | 2026-05-13 | 2028-04-11 | 17SS+30d | 1225d |  |  |
| 26 | 6.3.1.7 | Demolition and Clearing |  | 100d | 2026-08-05 | 2026-12-22 | 20SS+30d | 540d | 0d |  |

| ID | WBS | Task | Duration | Start | Finish | Predecessors | Total slack | Free slack |
| --- | --- | --- | --- | --- | --- | --- | --- | --- |
| 27 | 6.3.2 | **Saddle Dams** | 1025d | 2026-12-23 | 2030-11-26 |  | 540d | 0d |
| 28 | 6.3.2.1 | **Saddle Dam 3** | 750d | 2026-12-23 | 2029-11-06 |  | 540d |  |
| 29 | 6.3.2.1.1 | Saddle Dam 3 - Access and Staging | 50d | 2027-07-27 | 2027-10-04 | 21 | 626d | 0d |
| 30 | 6.3.2.1.2 | Erosion and Sediment Control | 50d | 2027-07-27 | 2027-10-04 | 29SS | 1361d |  |
| 31 | 6.3.2.1.3 | Clearing / Grubbing Topsoil Salvage from Work Areas | 50d | 2027-07-27 | 2027-10-04 | 29SS | 1361d |  |
| 32 | 6.3.2.1.4 | Demolition | 5d | 2027-10-05 | 2027-10-11 | 29SS+50d | 1356d |  |
| 33 | 6.3.2.1.5 | Saddle Dam 3 - Foundation Excavation | 150d | 2026-12-23 | 2027-07-20 | 26 | 540d | 0d |
| 34 | 6.3.2.1.6 | **Saddle Dam 3 - Foundation Preparation and Grouting** | 300d | 2027-03-31 | 2028-05-23 |  | 540d |  |
| 35 | 6.3.2.1.6.1 | Foundation Cleaning | 180d | 2027-03-31 | 2027-12-07 | 33SS+70d | 540d | 0d |
| 36 | 6.3.2.1.6.2 | Grout Cap | 80d | 2027-11-24 | 2028-03-14 | 38FS-10d | 540d | 0d |
| 37 | 6.3.2.1.6.3 | Curtain Grouting | 120d | 2027-12-08 | 2028-05-23 | 36SS+10d | 540d | 0d |
| 38 | 6.3.2.1.6.4 | Dental Excavation and Concrete | 180d | 2027-03-31 | 2027-12-07 | 35SS | 540d | 0d |
| 39 | 6.3.2.1.7 | **Saddle Dam 3 - Embankment** | 546d | 2027-10-05 | 2029-11-06 |  | 626d |  |
| 40 | 6.3.2.1.7.1 | Initial Borrow Development (Core Material) | 40d | 2027-10-05 | 2027-11-29 | 29 | 626d | 0d |
| 41 | 6.3.2.1.7.2 | Initial Quarry Development for Zones 3 and 4 | 120d | 2027-10-05 | 2028-03-20 | 29 | 1241d |  |
| 42 | 6.3.2.1.7.3 | Place Zone 1 - Core | 260d | 2028-03-01 | 2029-02-27 | 40SS+20d, 37SS+60d | 540d | 0d |
| 43 | 6.3.2.1.7.4 | Place Zone 2A & 2B - Filters, Drains and Transitions | 260d | 2028-03-01 | 2029-02-27 | 42SS | 815d | 0d |
| 44 | 6.3.2.1.7.5 | Place Zone 3 - Rockfill | 260d | 2028-03-01 | 2029-02-27 | 43SS | 815d | 0d |
| 45 | 6.3.2.1.7.6 | Place Zone 4 - Random | 260d | 2028-03-01 | 2029-02-27 | 44SS | 815d | 0d |
| 46 | 6.3.2.1.7.7 | Place Rip Rap | 200d | 2028-05-24 | 2029-02-27 | 45SS+60d | 815d | 0d |
| 47 | 6.3.2.1.7.8 | Site Reclamation and Topsoil Replacement | 180d | 2029-02-28 | 2029-11-06 | 46 | 815d |  |
| 48 | 6.3.2.2 | **Saddle Dam 5** | 700d | 2027-07-21 | 2030-03-26 |  | 715d |  |
| 49 | 6.3.2.2.1 | Saddle Dam 5 - Access and Staging | 30d | 2027-10-05 | 2027-11-15 | 29 | 826d | 0d |
| 50 | 6.3.2.2.2 | Erosion and Sediment Control | 30d | 2027-11-16 | 2027-12-27 | 49 | 1271d | 0d |
| 51 | 6.3.2.2.3 | Clearing / Grubbing Topsoil Salvage from Work Areas | 30d | 2027-12-28 | 2028-02-07 | 50 | 1271d |  |
| 52 | 6.3.2.2.4 | Demolition | 5d | 2027-12-14 | 2027-12-20 | 49SS+50d | 1306d |  |
| 53 | 6.3.2.2.5 | Saddle Dam 5 - Foundation Excavation | 50d | 2027-07-21 | 2027-09-28 | 33 | 740d | 0d |

| ID | WBS | Task | Duration | Start | Finish | Predecessors | Total slack | Free slack |
| --- | --- | --- | --- | --- | --- | --- | --- | --- |
| 54 | 6.3.2.2.6 | **Saddle Dam 5 - Foundation Preparation and Grouting** | 130d | 2027-12-08 | 2028-06-06 | 53SS+100d | 740d |  |
| 55 | 6.3.2.2.6.1 | Foundation Cleaning | 60d | 2027-12-08 | 2028-02-29 | 53SS+20d | 740d | 0d |
| 56 | 6.3.2.2.6.2 | Grout Cap | 40d | 2028-02-16 | 2028-04-11 | 58FS-10d | 740d | 0d |
| 57 | 6.3.2.2.6.3 | Curtain Grouting | 70d | 2028-03-01 | 2028-06-06 | 56SS+10d | 740d | 200d |
| 58 | 6.3.2.2.6.4 | Dental Excavation and Concrete | 60d | 2027-12-08 | 2028-02-29 | 55SS | 740d | 0d |
| 59 | 6.3.2.2.7 | **Saddle Dam 5 - Embankment** | 426d | 2027-11-30 | 2029-07-17 |  | 846d |  |
| 60 | 6.3.2.2.7.1 | Initial Borrow Development (Core Material) | 40d | 2027-11-30 | 2028-01-24 | 40 | 846d | 306d |
| 61 | 6.3.2.2.7.2 | Initial Quarry Development for Zones 3 and 4 | 120d | 2027-11-30 | 2028-05-15 | 40 | 1201d |  |
| 62 | 6.3.2.2.7.3 | Place Zone 1 - Core | 100d | 2029-02-28 | 2029-07-17 | 57SS+60d, 60SS+20d, 42 | 540d | 0d |
| 63 | 6.3.2.2.7.4 | Place Zone 2A & 2B - Filters, Drains and Transitions | 100d | 2029-02-28 | 2029-07-17 | 62SS | 715d | 0d |
| 64 | 6.3.2.2.7.5 | Place Zone 3 - Rockfill | 100d | 2029-02-28 | 2029-07-17 | 63SS | 715d | 0d |
| 65 | 6.3.2.2.7.6 | Place Zone 4 - Random | 100d | 2029-02-28 | 2029-07-17 | 64SS | 715d | 0d |
| 66 | 6.3.2.2.7.7 | Place Rip Rap | 70d | 2029-04-11 | 2029-07-17 | 65SS+30d | 715d | 0d |
| 67 | 6.3.2.2.8 | Site Reclamation and Topsoil Replacement | 180d | 2029-07-18 | 2030-03-26 | 66 | 715d |  |
| 68 | 6.3.2.3 | **Minor Saddle Dams (1,2,6,8A)** | 825d | 2027-09-29 | 2030-11-26 |  | 540d |  |
| 69 | 6.3.2.3.1 | Minor Saddle Dams - Access and Staging | 30d | 2027-11-16 | 2027-12-27 | 49 | 826d | 0d |
| 70 | 6.3.2.3.2 | Erosion and Sediment Control | 30d | 2027-11-16 | 2027-12-27 | 69SS | 1301d |  |
| 71 | 6.3.2.3.3 | Clearing / Grubbing Topsoil Salvage from Work Areas | 30d | 2027-11-16 | 2027-12-27 | 69SS | 1301d |  |
| 72 | 6.3.2.3.4 | Demolition | 5d | 2028-01-25 | 2028-01-31 | 69SS+50d | 1276d |  |
| 73 | 6.3.2.3.5 | Minor Saddle Dams - Foundation Excavation | 100d | 2027-09-29 | 2028-02-15 | 53 | 820d | 0d |
| 74 | 6.3.2.3.6 | **Minor Saddle Dams - Foundation Preparation and Grouting** | 170d | 2028-02-16 | 2028-10-10 |  | 820d |  |
| 75 | 6.3.2.3.6.1 | Foundation Cleaning | 100d | 2028-02-16 | 2028-07-04 | 73 | 820d | 0d |
| 76 | 6.3.2.3.6.2 | Grout Cap | 80d | 2028-03-15 | 2028-07-04 | 78SS+10d | 820d | 0d |
| 77 | 6.3.2.3.6.3 | Curtain Grouting | 140d | 2028-03-29 | 2028-10-10 | 76SS+10d | 820d | 280d |
| 78 | 6.3.2.3.6.4 | Dental Excavation and Concrete | 100d | 2028-03-01 | 2028-07-18 | 75SS+10d | 820d | 0d |

| ID | WBS | Task | Duration | Start | Finish | Predecessors | Total slack | Free slack |
| --- | --- | --- | --- | --- | --- | --- | --- | --- |
| 79 | 6.3.2.3.7 | **Minor Saddle Dams - Embankment** | 581d | 2027-12-28 | 2030-03-19 |  | 720d |  |
| 80 | 6.3.2.3.7.1 | Initial Borrow Development (Core Material) | 40d | 2027-12-28 | 2028-02-21 | 69 | 926d | 386d |
| 81 | 6.3.2.3.7.2 | Initial Quarry Development for Zones 3 and 4 | 120d | 2027-12-28 | 2028-06-12 | 69 | 1181d |  |
| 82 | 6.3.2.3.7.3 | Place Zone 1 - Core | 175d | 2029-07-18 | 2030-03-19 | 77SS+60d, 80SS+20d, 62 | 540d | 0d |
| 83 | 6.3.2.3.7.4 | Place Zone 2A & 2B - Filters, Drains and Transitions | 175d | 2029-07-18 | 2030-03-19 | 82SS | 540d | 0d |
| 84 | 6.3.2.3.7.5 | Place Zone 3 - Rockfill | 175d | 2029-07-18 | 2030-03-19 | 83SS | 540d | 0d |
| 85 | 6.3.2.3.7.6 | Place Zone 4 - Random | 175d | 2029-07-18 | 2030-03-19 | 84SS | 540d | 0d |
| 86 | 6.3.2.3.7.7 | Place Rip Rap | 145d | 2029-08-29 | 2030-03-19 | 85SS+30d | 540d | 0d |
| 87 | 6.3.2.3.8 | Site Reclamation and Topsoil Replacement | 180d | 2030-03-20 | 2030-11-26 | 86 | 540d |  |
| 88 | 6.3.2.4 | **Saddle Dam 8B - Spillway** | 257d | 2027-12-28 | 2028-12-20 | 69 | 1044d |  |
| 89 | 6.3.2.4.1 | Batch Plant Setup and Operational | 50d | 2027-12-28 | 2028-03-06 | 69 | 1251d |  |
| 90 | 6.3.2.4.2 | SD8 - Foundation Excavation | 20d | 2027-12-28 | 2028-01-24 | 69 | 1044d | 0d |
| 91 | 6.3.2.4.3 | SD8 - Foundation Cleaning | 20d | 2028-01-25 | 2028-02-21 | 90 | 1044d | 0d |
| 92 | 6.3.2.4.4 | SD8 - Dental Excavation and Concrete | 20d | 2028-02-08 | 2028-03-06 | 91SS+10d | 1044d | 0d |
| 93 | 6.3.2.4.5 | SD8 - Grout Cap | 12d | 2028-03-07 | 2028-03-22 | 92 | 1044d | 0d |
| 94 | 6.3.2.4.6 | SD 8 - Foundation Grouting | 45d | 2028-03-23 | 2028-05-24 | 93 | 1044d | 0d |
| 95 | 6.3.2.4.7 | SD 8 - Mass Concrete | 120d | 2028-05-25 | 2028-11-08 | 94 | 1044d | 0d |
| 96 | 6.3.2.4.8 | SD 8 - Bridge | 30d | 2028-11-09 | 2028-12-20 | 95 | 1044d |  |
| 97 | 6.3.2.4.9 | SD 8 - Clay Backfill | 20d | 2028-08-17 | 2028-09-13 | 95SS+60d | 1111d | 0d |
| 98 | 6.3.2.4.10 | SD 8 - Riprap and Drain Gravel | 3d | 2028-09-14 | 2028-09-18 | 97 | 1111d |  |
| 99 | 6.3.2.5 | **Emergency Release Structure No. 1** | 285d | 2027-12-28 | 2029-01-29 |  | 826d |  |
| 100 | 6.3.2.5.1 | **Develop Downstream Portal** | 65d | 2027-12-28 | 2028-03-27 | 29 | 826d | 0d |
| 101 | 6.3.2.5.1.1 | Portal Excavation | 65d | 2027-12-28 | 2028-03-27 | 69 | 826d | 0d |
| 102 | 6.3.2.5.1.2 | Rock Bolting | 65d | 2027-12-28 | 2028-03-27 | 101SS | 826d |  |
| 103 | 6.3.2.5.2 | Tunnel Excavation and Lining (12 ft) | 160d | 2028-03-28 | 2028-11-06 | 100 | 826d | 0d |

| ID | WBS | Task | Duration | Start | Finish | Predecessors | Total slack | Free slack |
| --- | --- | --- | --- | --- | --- | --- | --- | --- |
| 104 | 6.3.2.5.3 | **Develop Upstream Portal** | 65d | 2028-03-28 | 2028-06-26 | 100 | 1011d | 0d |
| 105 | 6.3.2.5.3.1 | Portal Excavation | 65d | 2028-03-28 | 2028-06-26 | 101 | 1011d | 0d |
| 106 | 6.3.2.5.3.2 | Rock Bolting | 65d | 2028-03-28 | 2028-06-26 | 105SS | 1011d |  |
| 107 | 6.3.2.5.4 | Outlet Structure Concrete | 70d | 2028-06-27 | 2028-10-02 | 104 | 1011d | 65d |
| 108 | 6.3.2.5.5 | Install 10-Ft Cut and Cover Pipe | 30d | 2028-11-07 | 2028-12-18 | 100, 103 | 1026d | 10d |
| 109 | 6.3.2.5.6 | Inlet Structure Concrete | 40d | 2028-11-07 | 2029-01-01 | 103, 104 | 1016d | 0d |
| 110 | 6.3.2.5.7 | ERS - 1 Completion and Restoration | 20d | 2029-01-02 | 2029-01-29 | 107, 108, 109 | 1016d |  |
| 111 | 6.3.2.6 | **Emergency Release Structure No. 2** | 410d | 2028-03-28 | 2029-10-22 |  | 826d |  |
| 112 | 6.3.2.6.1 | **Develop Downstream Portal** | 65d | 2028-03-28 | 2028-06-26 | 100 | 921d | 0d |
| 113 | 6.3.2.6.1.1 | Portal Excavation | 65d | 2028-03-28 | 2028-06-26 | 69 | 921d | 0d |
| 114 | 6.3.2.6.1.2 | Rock Bolting | 65d | 2028-03-28 | 2028-06-26 | 113SS | 921d |  |
| 115 | 6.3.2.6.2 | Tunnel Excavation and Lining | 160d | 2028-11-07 | 2029-06-18 | 112, 103 | 826d | 0d |
| 116 | 6.3.2.6.3 | **Develop Upstream Portal** | 65d | 2028-06-27 | 2028-09-25 | 112, 104 | 1046d | 190d |
| 117 | 6.3.2.6.3.1 | Portal Excavation | 65d | 2028-06-27 | 2028-09-25 | 113 | 1046d | 0d |
| 118 | 6.3.2.6.3.2 | Rock Bolting | 65d | 2028-06-27 | 2028-09-25 | 117SS | 1046d |  |
| 119 | 6.3.2.6.4 | Outlet Structure Concrete | 70d | 2029-06-19 | 2029-09-24 | 107, 112, 115 | 826d | 0d |
| 120 | 6.3.2.6.5 | Install 10-Ft Cut and Cover Pipe | 30d | 2029-06-19 | 2029-07-30 | 112, 115 | 866d | 40d |
| 121 | 6.3.2.6.6 | Inlet Structure Concrete | 40d | 2029-06-19 | 2029-08-13 | 115, 116 | 856d | 30d |
| 122 | 6.3.2.6.7 | ERS - 2 Completion and Restoration | 20d | 2029-09-25 | 2029-10-22 | 119, 120, 121 | 826d |  |
| 123 | 6.3.3 | **Inlet Outlet Facilities - Part of Construction Package #2** | 1015d | 2026-09-02 | 2030-07-23 |  | 722d |  |
| 124 | 6.3.3.1 | **Develop Downstream Portal** | 100d | 2026-09-02 | 2027-01-19 |  | 747d |  |
| 125 | 6.3.3.1.1 | Portal Excavation | 100d | 2026-09-02 | 2027-01-19 | 20SS+50d, 22SS+50d | 747d | 0d |
| 126 | 6.3.3.1.2 | Rock Bolting | 100d | 2026-09-02 | 2027-01-19 | 125SS | 747d | 25d |
| 127 | 6.3.3.2 | Intake Channel Excavation | 75d | 2026-12-23 | 2027-04-06 | 26 | 1582d |  |

| ID | WBS | Task | Type | Duration | Start | Finish | Predecessors | Total slack | Free slack | Constraint |
| --- | --- | --- | --- | --- | --- | --- | --- | --- | --- | --- |
| 128 | 6.3.3.3 | **Develop Upstream Portal** |  | 125d | 2026-09-02 | 2027-02-23 |  | 722d |  |  |
| 129 | 6.3.3.3.1 | Portal Excavation |  | 125d | 2026-09-02 | 2027-02-23 | 20SS+50d, 22SS+50d | 722d | 0d |  |
| 130 | 6.3.3.3.2 | Rock Bolting |  | 125d | 2026-09-02 | 2027-02-23 | 129SS | 1612d |  |  |
| 131 | 6.3.3.4 | **Tunnels Excavation and Lining (Double Shift)** |  | 660d | 2027-02-24 | 2029-09-04 |  | 722d |  |  |
| 132 | 6.3.3.4.1 | North Tunnel Excavation - Two Headings, Double Shift |  | 180d | 2027-02-24 | 2027-11-02 | 126, 129 | 722d | 0d |  |
| 133 | 6.3.3.4.2 | North Tunnel Lining |  | 180d | 2027-11-03 | 2028-07-11 | 132 | 1252d |  |  |
| 134 | 6.3.3.4.3 | South Tunnel Excvation - Double Shift |  | 300d | 2027-11-03 | 2028-12-26 | 132 | 722d | 0d |  |
| 135 | 6.3.3.4.4 | South Tunnel Lining |  | 180d | 2028-12-27 | 2029-09-04 | 134 | 952d |  |  |
| 136 | 6.3.3.5 | **Intake and Outlet Structures** |  | 410d | 2028-12-27 | 2030-07-23 |  | 722d |  |  |
| 137 | 6.3.3.5.1 | Intake Structure Foundation |  | 60d | 2028-12-27 | 2029-03-20 | 132, 134 | 722d | 0d |  |
| 138 | 6.3.3.5.2 | Tunnel Bifurcation |  | 90d | 2029-03-21 | 2029-07-24 | 137 | 982d |  |  |
| 139 | 6.3.3.5.3 | Intake Structure Concrete |  | 200d | 2029-03-21 | 2029-12-25 | 137 | 722d | 0d |  |
| 140 | 6.3.3.5.4 | Intake Structure Gates and Mechanical |  | 90d | 2029-12-26 | 2030-04-30 | 139 | 722d | 0d |  |
| 141 | 6.3.3.5.5 | Tower Access Bridge |  | 90d | 2029-12-26 | 2030-04-30 | 139 | 722d | 0d |  |
| 142 | 6.3.3.5.6 | I/O Completion and Restoration |  | 60d | 2030-05-01 | 2030-07-23 | 139, 140, 141 | 722d |  |  |
| 143 | 6.4 | Dams and I/O Ready for Commissioning | milestone | 1d | 2030-11-27 | 2030-11-27 | 19, 27 | 540d | 0d |  |
| 144 | 6.5 | Dams and I/O Startup and Commissioning |  | 90d | 2030-11-28 | 2031-04-02 | 143 | 540d | 0d |  |
| 145 | 6.6 | Dams and I/O Substantial Completion | milestone | 1d | 2031-04-03 | 2031-04-03 | 144 | 540d |  |  |
| 146 | 7 | **CONSTRUCTION PACKAGE #2 - CONVEYANCE FACILITIES** |  | 2884d | 2022-04-11 | 2033-04-28 |  | 0d |  |  |
| 147 | 7.1 | **CAISO Approval** |  | 885d | 2022-04-11 | 2025-08-29 |  | 1229d |  |  |
| 148 | 7.1.1 | **Prepare & Submit CAISO Package** |  | 265d | 2022-04-11 | 2023-04-14 |  | 1229d |  |  |
| 149 | 7.1.1.1 | Prepare Pump/Motor Package for Vendors to obtain Data |  | 40d | 2022-04-11 | 2022-06-03 |  | 1229d | 0d | start no earlier than 2022-04-11 |
| 150 | 7.1.1.2 | Pump Vendors Prepare & Send Data |  | 120d | 2022-06-06 | 2022-11-18 | 149 | 1229d | 0d |  |
| 151 | 7.1.1.3 | Prepare Hydropower Generator/Turbine Package for Vendors to Obtain Data |  | 40d | 2022-04-11 | 2022-06-03 | 149SS | 1229d | 0d |  |
| 152 | 7.1.1.4 | Generator/Turbine Vendors Prepare & Send Data |  | 120d | 2022-06-06 | 2022-11-18 | 151 | 1229d | 0d |  |
| 153 | 7.1.1.5 | HC Engineering Team provide info to ZGlobal |  | 30d | 2022-11-21 | 2022-12-30 | 150, 152 | 1229d | 0d |  |
| 154 | 7.1.1.6 | ZGlobal run models and prepare CAISO package |  | 50d | 2023-01-02 | 2023-03-10 | 153 | 1229d | 0d |  |
| 155 | 7.1.1.7 | Sites Review CAISO Package & Approve |  | 20d | 2023-03-13 | 2023-04-07 | 154 | 1229d | 0d |  |
| 156 | 7.1.1.8 | ZGlobal Submit CAISO Package |  | 5d | 2023-04-10 | 2023-04-14 | 155 | 1229d | 0d |  |

| ID | WBS | Task | Duration | Start | Finish | Predecessors | Baseline start | Baseline finish | Baseline duration | Total slack | Free slack | Constraint | Text1 |
| --- | --- | --- | --- | --- | --- | --- | --- | --- | --- | --- | --- | --- | --- |
| 157 | 7.1.2 | **Respond to CAISO** | 587d | 2023-06-01 | 2025-08-29 |  |  |  |  | 1229d |  |  |  |
| 158 | 7.1.2.1 | Scoping Meeting | 22d | 2023-06-01 | 2023-06-30 | 156FS+33d |  |  |  | 1229d | 0d |  |  |
| 159 | 7.1.2.2 | Phase 1 Study | 130d | 2023-07-03 | 2023-12-29 | 158 |  |  |  | 1229d | 0d |  |  |
| 160 | 7.1.2.3 | Phase 1 Results Meeting | 22d | 2024-01-01 | 2024-01-30 | 159 |  |  |  | 1229d | 0d |  |  |
| 161 | 7.1.2.4 | First Finanical Security Posting | 21d | 2024-03-01 | 2024-03-29 | 160FS+22d |  |  |  | 1229d | 0d |  |  |
| 162 | 7.1.2.5 | Phase II Study | 153d | 2024-05-01 | 2024-11-29 | 161FS+22d |  |  |  | 1229d | 0d |  |  |
| 163 | 7.1.2.6 | Phase II Results Meeting | 22d | 2024-12-02 | 2024-12-31 | 162 |  |  |  | 1229d | 0d |  |  |
| 164 | 7.1.2.7 | Transmission Plan Deliverability (Resource Adequacy Process) | 21d | 2025-03-03 | 2025-03-31 | 163FS+43d |  |  |  | 1229d | 0d |  |  |
| 165 | 7.1.2.8 | Second Financial Security Posting | 22d | 2025-05-01 | 2025-05-30 | 164FS+22d |  |  |  | 2064d |  |  |  |
| 166 | 7.1.2.9 | Draft Impact Analysis Issues | 22d | 2025-05-01 | 2025-05-30 | 164FS+22d |  |  |  | 1999d | 0d |  |  |
| 167 | 7.1.2.10 | Reassessment Results | 21d | 2025-08-01 | 2025-08-29 | 166FS+44d |  |  |  | 1999d |  |  |  |
| 168 | 7.1.2.11 | Receive Draft Interconnection Agreement from CAISO | 22d | 2025-05-01 | 2025-05-30 | 164SS+43d |  |  |  | 1229d | 0d |  |  |
| 169 | 7.1.2.12 | Negotiate Interconnection Agreement | 65d | 2025-06-02 | 2025-08-29 | 168 |  |  |  | 1229d | 0d |  |  |
| 170 | 3 | **Funks/TRR Pipelines (DSOD Jurisdictional)** | 1705d | 2022-09-01 | 2029-03-14 |  |  |  |  | 1076d |  |  |  |
| 171 | 3.3.1 | **Engineering** | 1090d | 2022-09-01 | 2026-11-04 |  |  |  |  | 1676d |  |  |  |
| 172 | 3.3.1 | Preliminary (30%) | 327d | 2022-09-01 | 2023-12-01 |  | 2022-06-01 | 2023-05-16 | 250d | 2354d | 0d | start no earlier than 2022-09-01 | HC-FTP-100 |
| 173 | 7.2.1.2 | Class 3 Cost Estimate | 100d | 2023-12-04 | 2024-04-19 | 172 |  |  |  | 2354d |  |  |  |
| 174 | 3.3.1 | Final (60%, 90%, 100%) | 300d | 2025-09-11 | 2026-11-04 | 7FS-80d | 2023-05-17 | 2024-07-09 | 300d | 886d | 0d |  | HC-FTP-110 |
| 175 | 3.3.3 | **Construction** | 585d | 2026-11-05 | 2029-01-31 |  |  |  |  | 886d |  |  |  |
| 176 | 3.3.3 | Submittals | 90d | 2026-11-05 | 2027-03-10 | 174 | 2024-11-13 | 2025-02-04 | 60d | 886d | 0d |  | HC-FTP-300 |
| 177 | 3.3.3 | Structures | 330d | 2027-03-11 | 2028-06-14 | 176 | 2025-02-05 | 2026-05-12 | 330d | 1196d | 120d |  | HC-FTP-310 |
| 178 | 3.3.3 | Pipelines | 450d | 2027-03-11 | 2028-11-29 | 176 | 2025-02-05 | 2026-08-18 | 400d | 886d | 0d |  | HC-FTP-320 |
| 179 | 3.3.3 | Testing | 45d | 2028-11-30 | 2029-01-31 | 177, 178 | 2026-08-19 | 2026-10-20 | 45d | 1076d | 0d |  | HC-FTP-330 |
| 180 | 3.3.4 | **Commissioning** | 30d | 2029-02-01 | 2029-03-14 |  |  |  |  | 1076d |  |  |  |
| 181 | 3.3.4 | Commission | 30d | 2029-02-01 | 2029-03-14 | 179 | 2026-10-21 | 2026-12-01 | 30d | 1076d |  |  | HC-FTP-400 |

| ID | WBS | Task | Duration | Start | Finish | Predecessors | Baseline start | Baseline finish | Baseline duration | Total slack | Free slack | Constraint | Text1 |
| --- | --- | --- | --- | --- | --- | --- | --- | --- | --- | --- | --- | --- | --- |
| 182 | 4 | **Transmission Powerlines** | 1835d | 2022-09-01 | 2029-09-12 |  |  |  |  | 946d |  |  |  |
| 183 | 4.4.1 | **Engineering** | 850d | 2022-09-01 | 2025-12-03 |  |  |  |  | 1136d |  |  |  |
| 184 | 4.4.1 | Preliminary (30%) | 327d | 2022-09-01 | 2023-12-01 |  | 2022-06-01 | 2023-06-13 | 270d | 1136d | 0d | start no earlier than 2022-09-01 | HC-TPL-100 |
| 185 | 7.3.1.2 | Class 3 Cost Estimate | 100d | 2023-12-04 | 2024-04-19 | 184 |  |  |  | 2354d |  |  |  |
| 186 | 4.4.1 | Final (60%, 90%, 100%) | 350d | 2024-08-01 | 2025-12-03 | 184FS+173d | 2023-06-14 | 2024-10-15 | 350d | 1136d | 0d |  | HC-TPL-110 |
| 187 | 4.4.3 | **Construction** | 955d | 2025-12-04 | 2029-08-01 |  |  |  |  | 886d |  |  |  |
| 188 | 4.4.3 | Submittals | 60d | 2025-12-04 | 2026-02-25 | 186 | 2025-02-19 | 2025-05-13 | 60d | 1136d | 0d |  | HC-TPL-300 |
| 189 | 4.4.3 | Procurement | 300d | 2026-02-26 | 2027-04-21 | 188 | 2025-05-14 | 2026-07-07 | 300d | 1136d | 0d |  | HC-TPL-310 |
| 190 | 4.4.3 | Towers/Powerlines to POI | 300d | 2027-04-22 | 2028-06-14 | 188, 189 | 2026-07-08 | 2027-08-31 | 300d | 1136d | 250d |  | HC-TPL-320 |
| 191 | 4.4.3 | Towers/Powerlines Funks/TRR | 330d | 2028-02-24 | 2029-05-30 | 178SS+250d, 188 | 2026-08-19 | 2027-11-23 | 330d | 886d | 0d |  | HC-TPL-330 |
| 192 | 4.4.3 | Testing | 45d | 2029-05-31 | 2029-08-01 | 189, 190, 191 | 2027-11-24 | 2028-01-25 | 45d | 886d | 0d |  | HC-TPL-340 |
| 193 | 4.4.4 | **Commissioning** | 30d | 2029-08-02 | 2029-09-12 |  |  |  |  | 946d |  |  |  |
| 194 | 4.4.4 | Commission | 30d | 2029-08-02 | 2029-09-12 | 192 | 2028-01-26 | 2028-03-07 | 30d | 946d |  |  | HC-TPL-400 |
| 195 | 5 | **Funks Reservoir** | 1981d | 2022-09-01 | 2030-04-04 |  |  |  |  | 800d |  |  |  |
| 196 | 5.5.1 | **Engineering** | 1456d | 2022-09-01 | 2028-03-30 |  |  |  |  | 1131d |  |  |  |
| 197 | 5.5.1 | Preliminary Design (30%) | 327d | 2022-09-01 | 2023-12-01 |  | 2022-06-01 | 2023-06-13 | 270d | 2354d | 0d | start no earlier than 2022-09-01 | HC-FRV-100 |
| 198 | 7.4.1.2 | Class 3 Cost Estimate | 100d | 2023-12-04 | 2024-04-19 | 197 |  |  |  | 2354d |  |  |  |
| 199 | 5.5.1 | Final 60% Design | 130d | 2026-01-01 | 2026-07-01 | 7 | 2023-06-14 | 2024-10-15 | 350d | 1781d |  |  | HC-FRV-110 |
| 200 | 7.4.1.4 | Final 90% Design | 130d | 2027-01-01 | 2027-07-01 | 8 |  |  |  | 0d |  |  |  |
| 201 | 7.4.1.5 | Final 100% Design | 195d | 2027-07-02 | 2028-03-30 | 200 |  |  |  | 0d |  |  |  |
| 202 | 5.5.3 | **Construction** | 495d | 2028-03-31 | 2030-02-21 |  |  |  |  | 0d |  |  |  |
| 203 | 5.5.3 | Submittals | 120d | 2028-03-31 | 2028-09-14 | 201 | 2025-02-19 | 2025-08-05 | 120d | 0d |  |  | HC-FRV-300 |
| 204 | 5.5.3 | Haulroads | 200d | 2028-09-15 | 2029-06-21 | 203 | 2025-08-06 | 2026-05-12 | 200d | 1005d |  |  | HC-FRV-310 |
| 205 | 5.5.3 | Sediment Removal | 250d | 2028-09-15 | 2029-08-30 | 203 | 2025-08-06 | 2026-07-21 | 250d | 0d |  |  | HC-FRV-320 |
| 206 | 5.5.3 | PGP Cofferdams (build) | 65d | 2029-08-31 | 2029-11-29 | 205 | 2026-07-22 | 2027-07-06 | 250d | 0d |  | start no earlier than 2025-12-01 | HC-FRV-330 |
| 207 | 5.5.3 | Pipeline Cofferdams (build) | 65d | 2029-08-31 | 2029-11-29 | 205 | 2026-07-22 | 2027-07-06 | 250d | 800d | 0d | start no earlier than 2026-12-01 | HC-FRV-330 |
| 208 | 5.5.3 | Testing | 60d | 2029-11-30 | 2030-02-21 | 206, 207 | 2027-07-07 | 2027-09-28 | 60d | 800d | 0d |  | HC-FRV-340 |

| ID | WBS | Task | Duration | Start | Finish | Predecessors | Baseline start | Baseline finish | Baseline duration | Total slack | Free slack | Constraint | Text1 |
| --- | --- | --- | --- | --- | --- | --- | --- | --- | --- | --- | --- | --- | --- |
| 209 | 5.5.4 | **Commissioning** | 30d | 2030-02-22 | 2030-04-04 |  |  |  |  | 800d |  |  |  |
| 210 | 5.5.4 | Commission | 30d | 2030-02-22 | 2030-04-04 | 208 | 2027-09-29 | 2027-11-09 | 30d | 800d |  |  | HC-FRV-400 |
| 211 | 6 | **Funks Pumping Generating Plant** | 2781d | 2022-09-01 | 2033-04-28 |  |  |  |  | 0d |  |  |  |
| 212 | 6.6.1 | **Engineering** | 900d | 2022-09-01 | 2026-02-11 |  |  |  |  | 871d |  |  |  |
| 213 | 6.6.1 | Preliminary (30%) | 327d | 2022-09-01 | 2023-12-01 |  | 2022-06-01 | 2023-06-13 | 270d | 871d | 0d | start no earlier than 2022-09-01 | HC-FPG-100 |
| 214 | 7.5.1.2 | Class 3 Cost Estimate | 100d | 2023-12-04 | 2024-04-19 | 213 |  |  |  | 2354d |  |  |  |
| 215 | 6.6.1 | Final (60%, 90%, 100%) | 400d | 2024-08-01 | 2026-02-11 | 213FS+173d | 2023-06-14 | 2024-10-15 | 350d | 871d | 0d |  | HC-FPG-110 |
| 216 | 6.6.3 | **Construction** | 1851d | 2026-02-12 | 2033-03-17 |  |  |  |  | 30d |  |  |  |
| 217 | 6.6.3 | Submittals | 120d | 2026-02-12 | 2026-07-29 | 215 | 2025-02-19 | 2025-08-05 | 120d | 871d | 0d |  | HC-FPG-300 |
| 218 | 6.6.3 | Large Equipment Procurement | 350d | 2026-07-30 | 2027-12-01 | 217 | 2025-08-06 | 2026-12-08 | 350d | 1411d |  |  | HC-FPG-310 |
| 219 | 6.6.3 | Structures | 800d | 2029-11-30 | 2032-12-23 | 217, 206 | 2025-08-06 | 2028-04-11 | 700d | 0d |  |  | HC-FPG-320 |
| 220 | 6.6.3 | Testing | 60d | 2032-12-24 | 2033-03-17 | 192, 219 | 2028-04-12 | 2028-07-04 | 60d | 0d |  |  | HC-FPG-330 |
| 221 | 6.6.4 | **Commissioning** | 30d | 2033-03-18 | 2033-04-28 |  |  |  |  | 0d |  |  |  |
| 222 | 6.6.4 | Commission | 30d | 2033-03-18 | 2033-04-28 | 220 | 2028-07-05 | 2028-08-15 | 30d | 0d |  |  | HC-FPG-400 |
| 223 | 7.6 | **Funks Substation** | 1552d | 2022-09-01 | 2028-08-11 |  |  |  |  | 1229d |  |  |  |
| 224 | 7.6.1 | **Engineering [Includes PG&E]** | 842d | 2022-09-01 | 2025-11-21 |  |  |  |  | 1541d |  |  |  |
| 225 | 7.6.1.1 | Design 30% | 300d | 2022-09-01 | 2023-10-25 | 156FF+30d |  |  |  | 2441d | 0d | start no earlier than 2022-09-01 |  |
| 226 | 7.6.1.2 | Class 3 Cost Estimate | 40d | 2023-10-26 | 2023-12-20 | 225 |  |  |  | 2441d |  |  |  |
| 227 | 7.6.1.3 | Design (60%, 90%, 100%) | 530d | 2023-11-13 | 2025-11-21 | 169FF+60d |  |  |  | 1229d | 0d |  |  |
| 228 | 7.6.2 | **Construction** | 500d | 2026-03-30 | 2028-02-25 |  |  |  |  | 1229d | 0d |  |  |
| 229 | 9.9.3 | Submittals | 100d | 2026-03-30 | 2026-08-14 | 227FS+90d | 2025-12-10 | 2026-05-26 | 120d | 1229d | 0d |  | HC-SUB-300 |
| 230 | 7.6.2.2 | Earthwork/Pad Prep | 150d | 2026-08-17 | 2027-03-12 | 229 |  |  |  | 1479d |  |  |  |
| 231 | 9.9.3 | Large Equipment Procurement | 150d | 2026-08-17 | 2027-03-12 | 229 | 2026-05-27 | 2027-05-11 | 250d | 1229d | 0d |  | HC-SUB-310 |
| 232 | 9.9.3 | Structures | 250d | 2027-03-15 | 2028-02-25 | 231 | 2026-05-27 | 2027-07-20 | 300d | 1229d |  |  | HC-SUB-320 |
| 233 | 7.6.3 | Commissioning | 120d | 2028-02-28 | 2028-08-11 | 228 |  |  |  | 1229d |  |  |  |

| ID | WBS | Task | Type | Duration | Start | Finish | Predecessors | Baseline start | Baseline finish | Baseline duration | Total slack | Free slack | Constraint | Text1 |
| --- | --- | --- | --- | --- | --- | --- | --- | --- | --- | --- | --- | --- | --- | --- |
| 234 | 7 | **TRR West Reservoir** |  | 2216d | 2022-09-01 | 2031-02-27 |  |  |  |  | 565d |  |  |  |
| 235 | 7.7.1 | **Engineering** |  | 1456d | 2022-09-01 | 2028-03-30 |  |  |  |  | 1325d |  |  |  |
| 236 | 7.7.1 | Preliminary (30%) |  | 327d | 2022-09-01 | 2023-12-01 |  | 2022-06-01 | 2023-06-13 | 270d | 2354d | 0d | start no earlier than 2022-09-01 | HC-TER-100 |
| 237 | 7.7.1.2 | Class 3 Cost Estimate |  | 100d | 2023-12-04 | 2024-04-19 | 236 |  |  |  | 2354d |  |  |  |
| 238 | 7.7.1.3 | Final 60% Design |  | 130d | 2026-01-01 | 2026-07-01 | 7 |  |  |  | 1781d |  | finish no earlier than 2026-07-01 |  |
| 239 | 7.7.1.4 | Final 90% Design |  | 130d | 2027-01-01 | 2027-07-01 | 8 |  |  |  | 565d | 0d | finish no earlier than 2027-07-01 |  |
| 240 | 7.7.1 | Final 100% Design |  | 195d | 2027-07-02 | 2028-03-30 | 239 | 2023-06-14 | 2024-10-15 | 350d | 565d | 0d | finish no earlier than 2028-03-30 | HC-TER-110 |
| 241 | 7.7.3 | **Construction** |  | 730d | 2028-03-31 | 2031-01-16 |  |  |  |  | 565d |  |  |  |
| 242 | 7.7.3 | Submittals |  | 120d | 2028-03-31 | 2028-09-14 | 240 | 2025-02-19 | 2025-08-05 | 120d | 565d | 0d |  | HC-TER-300 |
| 243 | 7.7.3 | Haulroads |  | 200d | 2028-09-15 | 2029-06-21 | 242 | 2025-08-06 | 2026-05-12 | 200d | 565d | 0d |  | HC-TER-310 |
| 244 | 7.7.3 | Earthwork/Structures |  | 300d | 2029-06-22 | 2030-08-15 | 243 | 2026-07-22 | 2027-09-14 | 300d | 565d | 0d |  | HC-TER-330 |
| 245 | 7.7.3 | Subgrade and Liner |  | 200d | 2030-01-18 | 2030-10-24 | 244FS-1200h | 2027-02-17 | 2027-11-23 | 200d | 565d | 0d |  | HC-TER-340 |
| 246 | 7.7.3 | Testing |  | 60d | 2030-10-25 | 2031-01-16 | 244, 245 | 2027-11-24 | 2028-02-15 | 60d | 565d | 0d |  | HC-TER-350 |
| 247 | 7.7.4 | **Commissioning** |  | 30d | 2031-01-17 | 2031-02-27 |  |  |  |  | 565d |  |  |  |
| 248 | 7.7.4 | Commission |  | 30d | 2031-01-17 | 2031-02-27 | 246 | 2028-02-16 | 2028-03-28 | 30d | 565d |  |  | HC-TER-400 |
| 249 | 8 | **TRR West Pumping Generating Plant** |  | 1895d | 2022-09-01 | 2029-12-05 |  |  |  |  | 0d |  |  |  |
| 250 | 8.8.1 | **Engineering** |  | 900d | 2022-09-01 | 2026-02-11 |  |  |  |  | 0d |  |  |  |
| 251 | 8.8.1 | Preliminary (30%) | manual | 327d | 2022-09-01 | 2023-12-01 |  | 2022-06-01 | 2023-06-13 | 270d |  |  | start no earlier than 2022-09-01 | HC-TPG-100 |
| 252 | 7.8.1.2 | Class 3 Cost Estimate |  | 100d | 2023-12-04 | 2024-04-19 | 251 |  |  |  | 2354d |  |  |  |
| 253 | 8.8.1 | Final (60%, 90%, 100%) |  | 400d | 2024-08-01 | 2026-02-11 | 251FS+173d | 2023-06-14 | 2024-10-15 | 350d | 971d | 0d |  | HC-TPG-110 |
| 254 | 8.8.3 | **Construction** |  | 965d | 2026-02-12 | 2029-10-24 |  |  |  |  | 916d |  |  |  |
| 255 | 8.8.3 | Submittals |  | 120d | 2026-02-12 | 2026-07-29 | 253 | 2025-02-19 | 2025-08-05 | 120d | 971d | 0d |  | HC-TPG-300 |
| 256 | 8.8.3 | Large Equipment Procurement |  | 355d | 2026-07-30 | 2027-12-08 | 255 | 2025-08-06 | 2026-12-15 | 355d | 1406d |  | start no earlier than 2022-10-10 | HC-TPG-310 |
| 257 | 8.8.3 | Structures |  | 700d | 2026-07-30 | 2029-04-04 | 255 | 2025-08-06 | 2028-04-11 | 700d | 971d | 85d |  | HC-TPG-320 |
| 258 | 8.8.3 | Testing |  | 60d | 2029-08-02 | 2029-10-24 | 192, 257 | 2028-04-12 | 2028-07-04 | 60d | 886d | 0d |  | HC-TPG-330 |

| ID | WBS | Task | Duration | Start | Finish | Predecessors | Baseline start | Baseline finish | Baseline duration | Total slack | Free slack | Constraint | Text1 |
| --- | --- | --- | --- | --- | --- | --- | --- | --- | --- | --- | --- | --- | --- |
| 259 | 8.8.4 | **Commissioning** | 30d | 2029-10-25 | 2029-12-05 |  |  |  |  | 886d |  |  |  |
| 260 | 8.8.4 | Commission | 30d | 2029-10-25 | 2029-12-05 | 258 | 2028-07-05 | 2028-08-15 | 30d | 886d |  |  | HC-TPG-400 |
| 261 | 9 | **TRR West Substation** | 1552d | 2022-09-01 | 2028-08-11 |  |  |  |  | 1229d |  |  |  |
| 262 | 9.9.1 | **Engineering [Includes PG&E]** | 842d | 2022-09-01 | 2025-11-21 |  |  |  |  | 1541d |  |  |  |
| 263 | 9.9.1 | Preliminary (30%) | 300d | 2022-09-01 | 2023-10-25 | 156FF+30d | 2022-06-01 | 2023-06-13 | 270d | 2441d | 0d | start no earlier than 2022-09-01 | HC-SUB-100 |
| 264 | 7.9.1.2 | Class 3 Cost Estimate | 40d | 2023-10-26 | 2023-12-20 | 263 |  |  |  | 2441d |  |  |  |
| 265 | 9.9.1 | Design (60%, 90%, 100%) | 530d | 2023-11-13 | 2025-11-21 | 169FF+60d | 2023-06-14 | 2024-10-15 | 350d | 1229d | 0d |  | HC-SUB-110 |
| 266 | 9.9.3 | **Construction** | 500d | 2026-03-30 | 2028-02-25 |  |  |  |  | 1229d | 0d |  |  |
| 267 | 9.9.3 | Submittals | 100d | 2026-03-30 | 2026-08-14 | 265FS+90d | 2025-12-10 | 2026-05-26 | 120d | 1229d | 0d |  | HC-SUB-300 |
| 268 | 7.9.2.2 | Earthwork/Pad Prep | 150d | 2026-08-17 | 2027-03-12 | 267 |  |  |  | 1479d |  |  |  |
| 269 | 9.9.3 | Large Equipment Procurement | 150d | 2026-08-17 | 2027-03-12 | 267 | 2026-05-27 | 2027-05-11 | 250d | 1229d | 0d |  | HC-SUB-310 |
| 270 | 9.9.3 | Structures | 250d | 2027-03-15 | 2028-02-25 | 269 | 2026-05-27 | 2027-07-20 | 300d | 1229d |  |  | HC-SUB-320 |
| 271 | 9.9.4 | **Commissioning** | 120d | 2028-02-28 | 2028-08-11 | 266 |  |  |  | 1229d |  |  |  |
| 272 | 9.9.4 | Commission | 120d | 2028-02-28 | 2028-08-11 | 266 | 2028-05-31 | 2028-07-11 | 30d | 1229d |  |  | HC-SUB-400 |
| 273 | 1 | **CONSTRUCTION PACKAGE #5 - DUNNIGAN PIPELINE** | 1275d | 2022-09-01 | 2027-07-21 |  |  |  |  | 1506d |  |  |  |
| 274 | 1.1.1 | **Engineering** | 800d | 2022-09-01 | 2025-09-24 |  |  |  |  | 1506d |  |  |  |
| 275 | 1.1.1 | Preliminary (30%) | 327d | 2022-09-01 | 2023-12-01 |  | 2022-06-01 | 2023-03-07 | 200d | 1506d | 0d | start no earlier than 2022-09-01 | HC-DP1-100 |
| 276 | 8.1.2 | Class 3 Cost Estimate | 100d | 2023-12-04 | 2024-04-19 | 275 |  |  |  | 2354d |  |  |  |
| 277 | 1.1.1 | Final (60%, 90%, 100%) | 300d | 2024-08-01 | 2025-09-24 | 275FS+173d | 2023-03-08 | 2024-02-20 | 250d | 1506d | 0d |  | HC-DP1-110 |
| 278 | 1.1.2 | **Bid and Award** | 90d | 2025-09-25 | 2026-01-28 |  |  |  |  | 1506d |  |  |  |
| 279 | 1.1.2 | Bid and Award | 90d | 2025-09-25 | 2026-01-28 | 277 | 2024-02-21 | 2024-06-25 | 90d | 1506d | 0d |  | HC-DP1-200 |
| 280 | 1.1.3 | **Construction** | 355d | 2026-01-29 | 2027-06-09 |  |  |  |  | 1506d |  |  |  |
| 281 | 1.1.3 | Submittals | 60d | 2026-01-29 | 2026-04-22 | 279 | 2024-06-26 | 2024-09-17 | 60d | 1506d | 0d |  | HC-DP1-300 |
| 282 | 1.1.3 | Structures | 240d | 2026-04-23 | 2027-03-24 | 281 | 2024-09-18 | 2025-08-19 | 240d | 1516d | 10d |  | HC-DP1-310 |
| 283 | 1.1.3 | Pipeline | 250d | 2026-04-23 | 2027-04-07 | 281 | 2024-09-18 | 2025-09-02 | 250d | 1506d | 0d |  | HC-DP1-320 |
| 284 | 1.1.3 | Testing | 45d | 2027-04-08 | 2027-06-09 | 282, 283 | 2025-09-03 | 2025-11-04 | 45d | 1506d | 0d |  | HC-DP1-330 |

| ID | WBS | Task | Duration | Start | Finish | Predecessors | Baseline start | Baseline finish | Baseline duration | Total slack | Free slack | Constraint | Text1 |
| --- | --- | --- | --- | --- | --- | --- | --- | --- | --- | --- | --- | --- | --- |
| 285 | 1.1.4 | **Commissioning** | 30d | 2027-06-10 | 2027-07-21 |  |  |  |  | 1506d |  |  |  |
| 286 | 1.1.4 | Commission | 30d | 2027-06-10 | 2027-07-21 | 284 | 2025-11-05 | 2025-12-16 | 30d | 1506d |  |  | HC-DP1-400 |
| 287 | 10 | **CONSTRUCTION PACKAGE #6 - RED BLUFF PUMPING PLANT (BY TCCA)** | 1050d | 2025-01-06 | 2029-01-12 |  |  |  |  | 1119d |  |  |  |
| 288 | 10.10.1 | **Engineering** | 210d | 2025-01-06 | 2025-10-24 |  |  |  |  | 1119d |  |  |  |
| 289 | 10.10.1 | Preliminary (30%) | 90d | 2025-01-06 | 2025-05-09 |  | 2023-01-02 | 2023-05-05 | 90d | 1119d | 0d | start no earlier than 2025-01-06 | HC-RBP-100 |
| 290 | 10.10.1 | Final (60%, 90%, 100%) | 120d | 2025-05-12 | 2025-10-24 | 289 | 2023-05-08 | 2023-10-20 | 120d | 1119d | 0d |  | HC-RBP-110 |
| 291 | 10.10.2 | **Bid and Award** | 90d | 2025-10-27 | 2026-02-27 |  |  |  |  | 1119d |  |  |  |
| 292 | 10.10.2 | Bid and Award | 90d | 2025-10-27 | 2026-02-27 | 290 | 2024-09-30 | 2025-01-31 | 90d | 1119d | 0d | start no earlier than 2024-09-30 | HC-RBP-200 |
| 293 | 10.10.3 | **Construction** | 720d | 2026-03-02 | 2028-12-01 |  |  |  |  | 1119d |  |  |  |
| 294 | 10.10.3 | Submittals | 120d | 2026-03-02 | 2026-08-14 | 292 | 2025-02-03 | 2025-07-18 | 120d | 1119d | 0d |  | HC-RBP-300 |
| 295 | 10.10.3 | Pump Procurement | 18mo | 2026-08-17 | 2027-12-31 | 294 | 2025-07-21 | 2026-04-24 | 200d | 1119d | 0d |  | HC-RBP-310 |
| 296 | 10.10.3 | Mechanical/Electrical | 180d | 2028-01-03 | 2028-09-08 | 295 | 2026-04-27 | 2027-01-01 | 180d | 1119d | 0d |  | HC-RBP-320 |
| 297 | 10.10.3 | Testing | 60d | 2028-09-11 | 2028-12-01 | 296 | 2027-01-04 | 2027-03-26 | 60d | 1119d | 0d |  | HC-RBP-330 |
| 298 | 10.10.4 | **Commissioning** | 30d | 2028-12-04 | 2029-01-12 |  |  |  |  | 1119d |  |  |  |
| 299 | 10.10.4 | Commission | 30d | 2028-12-04 | 2029-01-12 | 297 | 2027-03-29 | 2027-05-07 | 30d | 1119d |  |  | HC-RBP-400 |
| 300 | 11 | **CONSTRUCTION PACKAGE #7 - GCID IMPROVMENTS (BY GCID)** | 1220d | 2025-01-06 | 2029-09-07 |  |  |  |  | 949d |  |  |  |
| 301 | 11.11.1 | **Engineering** | 440d | 2025-01-06 | 2026-09-11 |  |  |  |  | 949d |  |  |  |
| 302 | 11.11.1 | Preliminary (30%) | 120d | 2025-01-06 | 2025-06-20 |  | 2022-06-01 | 2023-06-13 | 270d | 949d | 0d | start no earlier than 2025-01-06 | HC-GCI-100 |
| 303 | 11.11.1 | Final (60%, 90%, 100%) | 320d | 2025-06-23 | 2026-09-11 | 302 | 2023-06-14 | 2024-10-15 | 350d | 949d | 0d |  | HC-GCI-110 |
| 304 | 11.11.2 | **Bid and Award** | 90d | 2026-09-14 | 2027-01-15 |  |  |  |  | 949d |  |  |  |
| 305 | 11.11.2 | Bid and Award | 90d | 2026-09-14 | 2027-01-15 | 303 | 2024-10-16 | 2025-02-18 | 90d | 949d | 0d |  | HC-GCI-200 |
| 306 | 11.11.3 | **Construction** | 660d | 2027-01-18 | 2029-07-27 |  |  |  |  | 949d |  |  |  |
| 307 | 11.11.3 | Submittals | 120d | 2027-01-18 | 2027-07-02 | 305 | 2025-02-19 | 2025-08-05 | 120d | 949d | 0d |  | HC-GCI-300 |
| 308 | 11.11.3 | Structures | 24mo | 2027-07-05 | 2029-05-04 | 307 | 2025-08-06 | 2027-07-06 | 500d | 1039d |  |  | HC-GCI-310 |
| 309 | 11.11.3 | Earthwork | 24mo | 2027-07-05 | 2029-05-04 | 307 | 2025-08-06 | 2027-07-06 | 500d | 949d | 0d |  | HC-GCI-320 |
| 310 | 11.11.3 | Testing | 60d | 2029-05-07 | 2029-07-27 | 309 | 2027-07-07 | 2027-09-28 | 60d | 949d | 0d |  | HC-GCI-330 |

| ID | WBS | Task | Duration | Start | Finish | Predecessors | Baseline start | Baseline finish | Baseline duration | Total slack | Text1 |
| --- | --- | --- | --- | --- | --- | --- | --- | --- | --- | --- | --- |
| 311 | 11.11.4 | **Commissioning** | 30d | 2029-07-30 | 2029-09-07 |  |  |  |  | 949d |  |
| 312 | 11.11.4 | Commission | 30d | 2029-07-30 | 2029-09-07 | 310 | 2027-09-29 | 2027-11-09 | 30d | 949d | HC-GCI-400 |
