# Sites Reservoir Dams Construction - rev 6 11-09-20

Schedule from MS Project, 2022-10-04 to 2031-03-27.

## Calendars

- Standard: Mon-Fri 08:00-12:00, 13:00-17:00; Sat-Sun off.

## Schedule

| ID | WBS | Task | Type | Duration | Start | Finish | Predecessors | Total slack | Free slack | Constraint |
| --- | --- | --- | --- | --- | --- | --- | --- | --- | --- | --- |
| 1 | 1 | CWC Award of Funds | milestone, manual | 0d | 2023-12-01 | 2023-12-01 |  |  |  |  |
| 2 | 2 | Sites Board Approval/NTP for Phase 3 | manual | 23d | 2024-01-03 | 2024-02-02 | 1 |  |  | start no earlier than 2024-01-03 |
| 3 | 3 | Determine Engineering Procurement & Delivery Method | milestone, manual | 0d | 2024-05-01 | 2024-05-01 | 2 |  |  |  |
| 4 | 4 | CMAR Solicitation and Procurement |  | 8mo | 2024-05-01 | 2024-12-10 | 3 | 182d | 15d |  |
| 5 | 5 | **Real Estate** |  | 314d | 2022-10-04 | 2023-12-15 |  | 0d |  |  |
| 6 | 5.1 | **Land Acquisition** |  | 314d | 2022-10-04 | 2023-12-15 |  | 0d |  |  |
| 7 | 5.1.1 | Critical Land Acquisition - P2a Geotech (Dam Foundation & Grouting)(And I/O) | milestone | 0d | 2022-10-04 | 2022-10-04 |  | 238d |  |  |
| 8 | 5.1.2 | Critical Land Acquisition - P2a Geotech (Roads) | manual | 144d | 2023-05-30 | 2023-12-15 |  |  |  | must finish on 2023-05-29 |
| 9 | 5.2 | **Land Use** |  | 0d | 2023-05-29 | 2023-05-29 |  | 0d |  |  |
| 10 | 5.2.1 | Real Estate Access & Permitting (Geotech & Surveying) | milestone, manual | 0d | 2023-05-29 | 2023-05-29 |  |  |  | start no earlier than 2023-05-29 |
| 11 | 6 | **Environmental** |  | 360d | 2022-10-04 | 2024-02-19 |  | 1853d |  |  |
| 12 | 6.1 | Environmental Surveys |  | 6mo | 2022-10-04 | 2023-03-20 |  | 1853d | 0d |  |
| 13 | 6.2 | Environmental Permitting |  | 12mo | 2023-03-21 | 2024-02-19 | 12 | 1853d |  |  |
| 14 | 7 | **Water** |  | 343d? | 2022-10-04 | 2024-01-25 |  | 723d |  |  |
| 15 | 7.1 | Water Rights Acquisition (Permanent) |  | 1d? | 2022-10-04 | 2022-10-04 |  | 2212d |  |  |
| 16 | 7.2 | **Construction Water** |  | 30d | 2023-12-15 | 2024-01-25 |  | 410d |  |  |
| 17 | 7.2.1 | Acquisition of Construction Water | milestone | 0d | 2023-12-15 | 2023-12-15 |  | 410d | 0d | start no earlier than 2023-12-15 |
| 18 | 7.2.2 | Initial Development of Construction Water |  | 30d | 2023-12-15 | 2024-01-25 | 17 | 410d | 275d |  |
| 19 | 8 | **Sites Reservoir Geotechnical Investigations** |  | 610d | 2022-10-14 | 2025-02-13 |  | 0d |  |  |
| 20 | 8.1 | P1 Geotech Investigation (30% Cutoff) |  | 230d | 2022-10-14 | 2023-08-31 | 2, 10, 8 | -341d | 0d | finish no later than 2023-08-31 |
| 21 | 8.2 | P2a Geotech Investigation (Dam Foundations & Grouting)(and I-O) |  | 76w | 2023-09-01 | 2025-02-13 | 20, 7 | 0d |  | finish no later than 2025-02-13 |
| 22 | 8.3 | P2a Geotech Investigation (Roads) |  | 76w | 2023-09-01 | 2025-02-13 | 20 | 0d |  | finish no later than 2025-02-13 |
| 23 | 9 | **Inlet-Outlet Facilities** |  | 1975d | 2023-09-01 | 2031-03-27 |  | 0d |  |  |
| 24 | 9.1 | **Engineering - Dams** |  | 995d | 2023-09-01 | 2027-06-24 |  | 0d |  |  |
| 25 | 9.1.1 | **Inlet-Outlet Design** |  | 995d | 2023-09-01 | 2027-06-24 |  | 0d |  |  |
| 26 | 9.1.1.1 | **Inlet-Outlet Design** |  | 995d | 2023-09-01 | 2027-06-24 |  | 0d |  |  |
| 27 | 9.1.1.1.1 | Inlet-Outlet 30% Design |  | 151d | 2023-09-01 | 2024-03-29 | 20 | 0d |  | finish no later than 2024-03-29 |
| 28 | 9.1.1.1.2 | Inlet-Outlet Package Submittal | milestone | 0d | 2024-03-29 | 2024-03-29 | 20, 27 | 294d | 0d |  |
| 29 | 9.1.1.1.3 | DSOD Review of Inlet-Outlet 30% Design |  | 26w | 2024-04-01 | 2024-09-27 | 28 | 294d |  |  |
| 30 | 9.1.1.1.4 | Inlet-Outlet Geotech Data | milestone | 0d | 2025-02-13 | 2025-02-13 | 21 | 0d |  |  |
| 31 | 9.1.1.1.5 | Inlet-Outlet 60% Design |  | 39w | 2025-02-14 | 2025-11-13 | 30 | 0d |  |  |
| 32 | 9.1.1.1.6 | DSOD Review of Inlet-Outlet 60% Design |  | 26w | 2025-11-14 | 2026-05-14 | 31, 29 | 0d |  |  |
| 33 | 9.1.1.1.7 | Inlet-Outlet 90% Design |  | 13w | 2026-05-15 | 2026-08-13 | 32 | 0d |  |  |
| 34 | 9.1.1.1.8 | DSOD Review of Inlet-Outlet 90% Design |  | 26w | 2026-08-14 | 2027-02-11 | 33 | 0d |  |  |
| 35 | 9.1.1.1.9 | Inlet-Outlet 100% Design |  | 7w | 2027-02-12 | 2027-04-01 | 34 | 0d |  |  |
| 36 | 9.1.1.1.10 | DSOD Review of Inlet-Outlet 100% Design Package |  | 12w | 2027-04-02 | 2027-06-24 | 35 | 0d |  |  |
| 37 | 9.1.1.1.11 | Inlet-Outlet DSOD Approval Received | milestone | 0d | 2027-06-24 | 2027-06-24 | 36 | 0d |  |  |

Notes:
- 20: End Date different than Jeff / Jeff W. Notes: P1 only gives us 30% for *all* features including roads, see below
- 21: Jeff W. Notes: Add critical access roads to this group
- 27: Already started? Used 200 Days instead of 457 days / Jeff W. Notes: This could be considered a fixed NLT date
- 31: Used 39 weeks instead of 78 weeks / Jeff W. Notes: Reduce to 26 weeks
- 33: Used 25 weeks instead of 39 weeks
- 35: Maintained 13 weeks
- 37: Jeff W. Notes: Same Date as GG Fdn Approval

| ID | WBS | Task | Type | Duration | Start | Finish | Predecessors | Total slack | Free slack | Constraint | Jeff W. Notes | Construction Package |
| --- | --- | --- | --- | --- | --- | --- | --- | --- | --- | --- | --- | --- |
| 38 | 9.2 | **CMAR Procurement** |  | 195d | 2025-01-01 | 2025-09-30 |  | 167d |  |  |  |  |
| 39 | 9.2.1 | Award CMAR Contract | milestone | 0d | 2025-01-01 | 2025-01-01 | 4 | 167d | 0d | start no earlier than 2025-01-01 |  |  |
| 40 | 9.2.2 | Notice to Proceed |  | 6w | 2025-01-01 | 2025-02-11 | 39 | 167d | 0d |  |  |  |
| 41 | 9.2.3 | Early Submittals And Approvals - Dams |  | 90d | 2025-02-12 | 2025-06-17 | 40 | 167d | 0d |  |  |  |
| 42 | 9.2.4 | CMAR Mobilization |  | 6mo | 2025-04-16 | 2025-09-30 | 40, 41SS+45d, 17 | 167d | 0d |  | Same Date as GG Fdn Approval |  |
| 43 | 9.3 | **Roads, Bridges, Access, and Site Development** |  | 1220d | 2025-02-13 | 2029-10-18 | 18 | 135d |  |  |  |  |
| 44 | 9.3.1 | Early Site Access and Staging Development |  | 100d | 2025-04-16 | 2025-09-02 | 42SS | 1452d |  |  |  |  |
| 45 | 9.3.2 | **Northern Construction Access Roads (CR 68, CR 69, N. Rd)** |  | 569d | 2025-02-13 | 2027-04-21 |  | 1026d |  |  |  |  |
| 46 | 9.3.2.1 | Geotechnical Data | milestone | 0d | 2025-02-13 | 2025-02-13 | 22 | 1026d | 0d |  | Assume P2a (Roads) |  |
| 47 | 9.3.2.2 | Final Design |  | 39w | 2025-02-14 | 2025-11-13 | 46 | 1026d | 0d |  |  |  |
| 48 | 9.3.2.3 | Procurement and NTP |  | 90d | 2025-11-14 | 2026-03-19 | 42, 47 | 1026d | 0d |  |  |  |
| 49 | 9.3.2.4 | Northern Construction Access Roads (CR 68, CR 69, N. Rd) |  | 284d | 2026-03-20 | 2027-04-21 | 48 | 1026d |  |  |  | C1-RB1 |
| 50 | 9.3.3 | **County Roads F, D, McDermott, Delevan** |  | 550d | 2025-02-13 | 2027-03-25 |  | 1045d |  |  |  |  |
| 51 | 9.3.3.1 | Geotechnical Data | milestone | 0d | 2025-02-13 | 2025-02-13 | 22 | 1045d | 0d |  | Assume P2a (Roads) |  |
| 52 | 9.3.3.2 | Final Design |  | 52w | 2025-02-14 | 2026-02-12 | 51 | 1045d | 0d |  |  |  |
| 53 | 9.3.3.3 | Procurement and NTP |  | 90d | 2026-02-13 | 2026-06-18 | 42, 52 | 1045d | 0d |  |  |  |
| 54 | 9.3.3.4 | County Roads F, D, McDermott, Delevan |  | 200d | 2026-06-19 | 2027-03-25 | 53 | 1045d |  |  |  | C1-RB2 |
| 55 | 9.3.4 | **Southern Construction Access Roads (Maxwell-Sites, Shoo-fly, A-1)** |  | 480d | 2025-02-13 | 2026-12-17 |  | 135d |  |  |  |  |
| 56 | 9.3.4.1 | Geotechnical Data | milestone | 0d | 2025-02-13 | 2025-02-13 | 22 | 135d | 0d |  | Assume P2a (Roads) |  |
| 57 | 9.3.4.2 | Final Design |  | 39w | 2025-02-14 | 2025-11-13 | 56 | 135d | 0d |  |  |  |
| 58 | 9.3.4.3 | Procurement and NTP |  | 90d | 2025-11-14 | 2026-03-19 | 42, 57 | 135d | 0d |  |  |  |
| 59 | 9.3.4.4 | Southern Construction Access Roads (Maxwell-Sites, Shoo-fly, A-1) |  | 195d | 2026-03-20 | 2026-12-17 | 58 | 135d |  |  |  | C1-RB3 |
| 60 | 9.3.5 | **Ancillary Roads B1, B2, C1, C2, Comm N., Comm South** |  | 505d | 2025-02-13 | 2027-01-21 |  | 1090d |  |  |  |  |
| 61 | 9.3.5.1 | Geotechnical Data | milestone | 0d | 2025-02-13 | 2025-02-13 | 22 | 1090d | 0d |  | Assume P2a (Roads) |  |
| 62 | 9.3.5.2 | Final Design |  | 39w | 2025-02-14 | 2025-11-13 | 61 | 1090d | 0d |  |  |  |
| 63 | 9.3.5.3 | Procurement and NTP |  | 90d | 2025-11-14 | 2026-03-19 | 42, 62 | 1090d | 0d |  |  |  |
| 64 | 9.3.5.4 | Ancillary Roads B1, B2, C1, C2, Comm N., Comm South |  | 220d | 2026-03-20 | 2027-01-21 | 63 | 1090d |  |  |  | C1-RB4 |

Notes:
- 39: Jeff's Dates
- 40: Jeff's Dates

| ID | WBS | Task | Type | Duration | Start | Finish | Predecessors | Total slack | Free slack | Jeff W. Notes | Construction Package |
| --- | --- | --- | --- | --- | --- | --- | --- | --- | --- | --- | --- |
| 65 | 9.3.6 | **Stone Corral Recreation Road to Sites Dam** |  | 405d | 2025-02-13 | 2026-09-03 |  | 1190d |  |  |  |
| 66 | 9.3.6.1 | Geotechnical Data | milestone | 0d | 2025-02-13 | 2025-02-13 | 22 | 1190d | 0d | Does this need to be this early? If not, assume P2b |  |
| 67 | 9.3.6.2 | Final Design |  | 39w | 2025-02-14 | 2025-11-13 | 66 | 1190d | 0d |  |  |
| 68 | 9.3.6.3 | Procurement and NTP |  | 90d | 2025-11-14 | 2026-03-19 | 42, 67 | 1190d | 0d |  |  |
| 69 | 9.3.6.4 | Stone Corral Recreation Road to Sites Dam |  | 120d | 2026-03-20 | 2026-09-03 | 68 | 1190d |  |  | C1-RB5 |
| 70 | 9.3.7 | **Sites Lodoga Road Realignment and Bridge** |  | 1220d | 2025-02-13 | 2029-10-18 |  | 375d |  |  |  |
| 71 | 9.3.7.1 | Geotechnical Data | milestone | 0d | 2025-02-13 | 2025-02-13 | 22 | 375d | 0d | Assume P2b data date |  |
| 72 | 9.3.7.2 | Final Design |  | 78w | 2025-02-14 | 2026-08-13 | 71 | 375d | 0d |  |  |
| 73 | 9.3.7.3 | Procurement and NTP |  | 150d | 2026-08-14 | 2027-03-11 | 42, 72 | 375d | 0d |  |  |
| 74 | 9.3.7.4 | Sites Lodoga Road Realignment and Bridge |  | 680d | 2027-03-12 | 2029-10-18 | 73 | 375d |  |  | C1-RB6 |
| 75 | 9.4 | **Inlet-Outlet Preliminary Work** |  | 100d | 2027-06-25 | 2027-11-11 |  | 0d |  |  |  |
| 76 | 9.4.1 | Inlet-Outlet Access and Staging |  | 100d | 2027-06-25 | 2027-11-11 | 42, 37, 8, 55, 18, 59 | 0d |  | Same Date as GG Fdn Approval |  |
| 77 | 9.4.2 | Erosion and Sediment Control |  | 100d | 2027-06-25 | 2027-11-11 | 76SS | 0d |  |  |  |
| 78 | 9.4.3 | Clearing / Grubbing Topsoil Salvage from Work Areas |  | 100d | 2027-06-25 | 2027-11-11 | 76SS | 0d |  |  |  |
| 79 | 9.4.4 | Demolition |  | 50d | 2027-07-09 | 2027-09-16 | 76SS+10d | 40d |  |  |  |
| 80 | 9.5 | **Inlet Outlet Facilities** |  | 880d | 2027-11-12 | 2031-03-27 |  | 0d |  |  |  |
| 81 | 9.5.1 | **Develop Downstream Portal** |  | 80d | 2027-11-12 | 2028-03-02 |  | 0d |  |  |  |
| 82 | 9.5.1.1 | Downstream Portal Excavation |  | 80d | 2027-11-12 | 2028-03-02 | 37, 42, 76, 77, 78, 79 | 0d |  |  |  |
| 83 | 9.5.1.2 | Downstream Portal Rock Bolting |  | 80d | 2027-11-12 | 2028-03-02 | 82SS | 0d |  |  |  |
| 84 | 9.5.2 | **Develop Upstream Portal** |  | 185d | 2027-11-12 | 2028-07-27 |  | 195d |  |  |  |
| 85 | 9.5.2.1 | Intake Channel Excavation |  | 60d | 2027-11-12 | 2028-02-03 | 37, 42, 76 | 195d | 0d |  |  |
| 86 | 9.5.2.2 | Upstream Portal Excavation |  | 125d | 2028-02-04 | 2028-07-27 | 85 | 195d | 0d |  |  |
| 87 | 9.5.2.3 | Upstream Portal Rock Bolting |  | 125d | 2028-02-04 | 2028-07-27 | 86SS | 195d |  |  |  |
| 88 | 9.5.3 | **Tunnels Excavation and Lining (Double Shift)** |  | 480d | 2028-03-03 | 2030-01-03 |  | 0d |  |  |  |
| 89 | 9.5.3.1 | Tunnel Excavation - Double Shift |  | 300d | 2028-03-03 | 2029-04-26 | 83 | 0d |  |  |  |
| 90 | 9.5.3.2 | Tunnel Lining |  | 180d | 2029-04-27 | 2030-01-03 | 89 | 230d |  |  |  |

| ID | WBS | Task | Type | Duration | Start | Finish | Predecessors | Total slack | Jeff W. Notes |
| --- | --- | --- | --- | --- | --- | --- | --- | --- | --- |
| 91 | 9.5.4 | **Intake and Outlet Structures** |  | 500d | 2029-04-27 | 2031-03-27 |  | 0d |  |
| 92 | 9.5.4.1 | Intake Structure Foundation |  | 60d | 2029-04-27 | 2029-07-19 | 89, 87 | 0d |  |
| 93 | 9.5.4.2 | Intake Structure Concrete |  | 200d | 2029-07-20 | 2030-04-25 | 92 | 0d |  |
| 94 | 9.5.4.3 | Intake Structure Gates and Mechanical |  | 90d | 2030-04-26 | 2030-08-29 | 92, 93 | 0d |  |
| 95 | 9.5.4.4 | I/O Completion and Restoration |  | 60d | 2030-08-30 | 2030-11-21 | 93, 94 | 0d |  |
| 96 | 9.5.4.5 | Inlet-Outlet Ready for Commissioning | milestone | 0d | 2030-11-21 | 2030-11-21 | 95, 90 | 0d |  |
| 97 | 9.5.4.6 | Inlet-Outlet Startup and Commissioning |  | 90d | 2030-11-22 | 2031-03-27 | 96 | 0d |  |
| 98 | 9.5.4.7 | Inlet-Outlet Completion | milestone | 0d | 2031-03-27 | 2031-03-27 | 97 | 0d | One Month after Dams Project C1 |
