# Maxwell Sites Pumping and Generating Facilities CP2

Schedule from MS Project, 2022-01-03 to 2031-05-08.

## Calendars

- Standard: Mon-Fri 08:00-12:00, 13:00-17:00; Sat-Sun off.

## Schedule

| ID | WBS | Task | Type | Duration | Start | Finish | Predecessors | Total slack | Free slack | Constraint |
| --- | --- | --- | --- | --- | --- | --- | --- | --- | --- | --- |
| 1 | 1 | Start Task Order 3 - Preliminary Engineering | milestone | 0d | 2022-01-03 | 2022-01-03 |  | 2453d |  | start no earlier than 2022-01-03 |
| 2 | 2 | Determine Construction Packaging & Delivery Methods | manual | 149d | 2022-01-03 | 2022-07-28 |  |  |  |  |
| 3 | 3 | Real Estate Team Gain Access for Surveying & Geotech Investigation |  | 500d | 2022-01-17 | 2024-02-16 |  | 1898d |  | start no earlier than 2022-01-17 |
| 4 | 4 | Topographic Survey and Mapping |  | 225d | 2022-01-03 | 2022-11-11 |  | 2228d |  | finish no earlier than 2022-11-11 |
| 5 | 5 | Water Rights Permit Issued | milestone | 0d | 2024-09-26 | 2024-09-26 |  | 330d | 69d | start no earlier than 2024-09-26 |
| 6 | 6 | Final EIR / EIS | milestone | 0d | 2023-05-05 | 2023-05-05 |  | 694d | 433d | start no earlier than 2023-05-05 |
| 7 | 7 | ROD Signed | milestone | 0d | 2023-08-07 | 2023-08-07 |  | 628d | 367d | start no earlier than 2023-08-07 |
| 8 | 8 | WIFEA EPA Loan Closed | milestone | 0d | 2024-10-31 | 2024-10-31 |  | 305d | 44d | start no earlier than 2024-10-31 |
| 9 | 9 | Investor Commitment | milestone | 0d | 2024-10-24 | 2024-10-24 |  | 1720d |  | start no earlier than 2024-10-24 |
| 10 | 10 | NTP for 60% Design Activities | milestone | 0d | 2025-01-01 | 2025-01-01 |  | 261d | 0d | start no earlier than 2025-01-01 |
| 11 | 11 | **Geotech Investigations MSPG Investigations** |  | 1002d | 2022-03-01 | 2025-12-31 |  | 6d |  |  |
| 12 | 11.1 | Phase 1 Geotech investigation for Preliminary (30%) Design |  | 741d | 2022-03-01 | 2024-12-31 |  | 6d | 0d | start no earlier than 2022-03-01 |
| 13 | 11.2 | Phase 2 Geotech Investigation for All MSPG Design |  | 261d | 2025-01-01 | 2025-12-31 | 12 | 6d | 0d |  |
| 14 | 12 | **Sites Reservoir Geotechnical Investigations** |  | 610d | 2022-10-14 | 2025-02-13 |  | 0d |  |  |
| 15 | 12.1 | P1 Geotech Investigation (30% Cutoff) | manual | 230d | 2022-10-14 | 2023-08-31 |  |  |  | start no earlier than 2022-10-14 |
| 16 | 12.2 | P2a Geotech Investigation (Dam Foundations & Grouting)(and I-O) |  | 76w | 2023-09-01 | 2025-02-13 | 15 | 0d |  | finish no later than 2025-02-13 |
| 17 | 12.3 | P2a Geotech Investigation (Roads) |  | 76w | 2023-09-01 | 2025-02-13 | 15 | 0d |  | finish no later than 2025-02-13 |
| 18 | 13 | **CONSTRUCTION PACKAGE #1 - RESERVOIR FACILITIES (Rev 7 10-25-22)** |  | 1999d | 2023-09-01 | 2031-04-30 |  | 0d |  |  |
| 19 | 13.1 | **Engineering - Dams** |  | 995d | 2023-09-01 | 2027-06-24 |  | 0d |  |  |
| 20 | 13.1.1 | **Inlet-Outlet Design** |  | 995d | 2023-09-01 | 2027-06-24 |  | 0d |  |  |
| 21 | 13.1.1.1 | **Inlet-Outlet Design (CP#2 - MSPG)** |  | 995d | 2023-09-01 | 2027-06-24 |  | 0d |  |  |
| 22 | 13.1.1.1.1 | Inlet-Outlet 30% Design |  | 151d | 2023-09-01 | 2024-03-29 | 15 | 0d |  | finish no later than 2024-03-29 |
| 23 | 13.1.1.1.2 | Inlet-Outlet Package Submittal | milestone | 0d | 2024-03-29 | 2024-03-29 | 22, 15 | 308d | 0d |  |
| 24 | 13.1.1.1.3 | DSOD Review of Inlet-Outlet 30% Design |  | 26w | 2024-04-01 | 2024-09-27 | 23 | 308d | 294d |  |
| 25 | 13.1.1.1.4 | Inlet-Outlet Geotech Data | milestone | 0d | 2025-02-13 | 2025-02-13 | 16 | 0d |  |  |
| 26 | 13.1.1.1.5 | Inlet-Outlet 60% Design |  | 39w | 2025-02-14 | 2025-11-13 | 25 | 0d |  |  |
| 27 | 13.1.1.1.6 | DSOD Review of Inlet-Outlet 60% Design |  | 26w | 2025-11-14 | 2026-05-14 | 24, 26 | 0d |  |  |
| 28 | 13.1.1.1.7 | Inlet-Outlet 90% Design |  | 13w | 2026-05-15 | 2026-08-13 | 27 | 0d |  |  |
| 29 | 13.1.1.1.8 | DSOD Review of Inlet-Outlet 90% Design |  | 26w | 2026-08-14 | 2027-02-11 | 28 | 0d |  |  |
| 30 | 13.1.1.1.9 | Inlet-Outlet 100% Design |  | 7w | 2027-02-12 | 2027-04-01 | 29 | 0d |  |  |
| 31 | 13.1.1.1.10 | DSOD Review of Inlet-Outlet 100% Design Package |  | 12w | 2027-04-02 | 2027-06-24 | 30 | 0d |  |  |
| 32 | 13.1.1.1.11 | Inlet-Outlet DSOD Approval Received | milestone | 0d | 2027-06-24 | 2027-06-24 | 31 | 0d |  |  |

Notes:
- 15: End Date different than Jeff / Text2: P1 only gives us 30% for *all* features including roads, see below
- 16: Text2: Add critical access roads to this group
- 22: Already started? Used 200 Days instead of 457 days / Text2: This could be considered a fixed NLT date
- 26: Used 39 weeks instead of 78 weeks / Text2: Reduce to 26 weeks
- 28: Used 25 weeks instead of 39 weeks
- 30: Maintained 13 weeks
- 32: Text2: Same Date as GG Fdn Approval

| ID | WBS | Task | Type | Duration | Start | Finish | Predecessors | Total slack | Free slack | Constraint | Text2 | Text3 |
| --- | --- | --- | --- | --- | --- | --- | --- | --- | --- | --- | --- | --- |
| 33 | 13.2 | **CMAR Procurement** |  | 195d | 2025-01-01 | 2025-09-30 |  | 167d |  |  |  |  |
| 34 | 13.2.1 | Award CMAR Contract | milestone | 0d | 2025-01-01 | 2025-01-01 |  | 181d | 0d | start no earlier than 2025-01-01 |  |  |
| 35 | 13.2.2 | Notice to Proceed |  | 6w | 2025-01-01 | 2025-02-11 | 34 | 181d | 0d |  |  |  |
| 36 | 13.2.3 | Early Submittals And Approvals - Dams and I/O |  | 90d | 2025-02-12 | 2025-06-17 | 35 | 181d | 0d |  |  |  |
| 37 | 13.2.4 | CMAR Mobilization |  | 6mo | 2025-04-16 | 2025-09-30 | 35, 36SS+45d | 181d | 0d |  | Same Date as GG Fdn Approval |  |
| 38 | 13.3 | **Roads, Bridges, Access, and Site Development** |  | 505d | 2025-02-13 | 2027-01-21 |  | 135d |  |  |  |  |
| 39 | 13.3.1 | Early Site Access and Staging Development |  | 100d | 2025-04-16 | 2025-09-02 | 37SS | 1496d |  |  |  |  |
| 40 | 13.3.2 | **Southern Construction Access Roads (Maxwell-Sites, Shoo-fly, A-1)** |  | 480d | 2025-02-13 | 2026-12-17 |  | 135d |  |  |  |  |
| 41 | 13.3.2.1 | Geotechnical Data | milestone | 0d | 2025-02-13 | 2025-02-13 | 17 | 149d | 0d |  | Assume P2a (Roads) |  |
| 42 | 13.3.2.2 | Final Design |  | 39w | 2025-02-14 | 2025-11-13 | 41 | 149d | 0d |  |  |  |
| 43 | 13.3.2.3 | Procurement and NTP |  | 90d | 2025-11-14 | 2026-03-19 | 37, 42 | 149d | 0d |  |  |  |
| 44 | 13.3.2.4 | Southern Construction Access Roads (Maxwell-Sites, Shoo-fly, A-1) |  | 195d | 2026-03-20 | 2026-12-17 | 43 | 149d |  |  |  | C1-RB3 |
| 45 | 13.3.3 | **Ancillary Roads B1, B2, C1, C2, Comm N., Comm South** |  | 505d | 2025-02-13 | 2027-01-21 |  | 1120d |  |  |  |  |
| 46 | 13.3.3.1 | Geotechnical Data | milestone | 0d | 2025-02-13 | 2025-02-13 | 17 | 1134d | 0d |  | Assume P2a (Roads) |  |
| 47 | 13.3.3.2 | Final Design |  | 39w | 2025-02-14 | 2025-11-13 | 46 | 1134d | 0d |  |  |  |
| 48 | 13.3.3.3 | Procurement and NTP |  | 90d | 2025-11-14 | 2026-03-19 | 37, 47 | 1134d | 0d |  |  |  |
| 49 | 13.3.3.4 | Ancillary Roads B1, B2, C1, C2, Comm N., Comm South |  | 220d | 2026-03-20 | 2027-01-21 | 48 | 1134d |  |  |  | C1-RB4 |
| 50 | 13.4 | **Inlet-Outlet Preliminary Work (CP#2 - MSPG)** |  | 100d | 2027-06-25 | 2027-11-11 |  | 0d |  |  |  |  |
| 51 | 13.4.1 | Inlet-Outlet Access and Staging |  | 100d | 2027-06-25 | 2027-11-11 | 32, 37, 40 | 0d |  |  | Same Date as GG Fdn Approval |  |
| 52 | 13.4.2 | Erosion and Sediment Control |  | 100d | 2027-06-25 | 2027-11-11 | 51SS | 0d |  |  |  |  |
| 53 | 13.4.3 | Clearing / Grubbing Topsoil Salvage from Work Areas |  | 100d | 2027-06-25 | 2027-11-11 | 51SS | 0d |  |  |  |  |
| 54 | 13.4.4 | Demolition |  | 50d | 2027-07-09 | 2027-09-16 | 51SS+10d | 54d | 40d |  |  |  |
| 55 | 13.5 | **Inlet Outlet Facilities (CP#2 - MSPG)** |  | 904d | 2027-11-12 | 2031-04-30 |  | 0d |  |  |  |  |
| 56 | 13.5.1 | **Develop Downstream Portal** |  | 80d | 2027-11-12 | 2028-03-02 |  | 0d |  |  |  |  |
| 57 | 13.5.1.1 | Downstream Portal Excavation |  | 80d | 2027-11-12 | 2028-03-02 | 32, 37, 51, 52, 53, 54 | 0d |  |  |  |  |
| 58 | 13.5.1.2 | Downstream Portal Rock Bolting |  | 80d | 2027-11-12 | 2028-03-02 | 57SS | 0d |  |  |  |  |

Notes:
- 34: Jeff's Dates
- 35: Jeff's Dates

| ID | WBS | Task | Type | Duration | Start | Finish | Predecessors | Total slack | Free slack | Constraint | Text2 |
| --- | --- | --- | --- | --- | --- | --- | --- | --- | --- | --- | --- |
| 59 | 13.5.2 | **Develop Upstream Portal** |  | 185d | 2027-11-12 | 2028-07-27 |  | 195d |  |  |  |
| 60 | 13.5.2.1 | Intake Channel Excavation |  | 60d | 2027-11-12 | 2028-02-03 | 32, 37, 51 | 209d | 0d |  |  |
| 61 | 13.5.2.2 | Upstream Portal Excavation |  | 125d | 2028-02-04 | 2028-07-27 | 60 | 209d | 0d |  |  |
| 62 | 13.5.2.3 | Upstream Portal Rock Bolting |  | 125d | 2028-02-04 | 2028-07-27 | 61SS | 209d | 195d |  |  |
| 63 | 13.5.3 | **Tunnels Excavation and Lining (Double Shift)** |  | 480d | 2028-03-03 | 2030-01-03 |  | 0d |  |  |  |
| 64 | 13.5.3.1 | Tunnel Excavation - Double Shift |  | 300d | 2028-03-03 | 2029-04-26 | 58 | 0d |  |  |  |
| 65 | 13.5.3.2 | Tunnel Lining |  | 180d | 2029-04-27 | 2030-01-03 | 64 | 274d | 230d |  |  |
| 66 | 13.5.4 | **Intake and Outlet Structures** |  | 524d | 2029-04-27 | 2031-04-30 |  | 0d |  |  |  |
| 67 | 13.5.4.1 | Intake Structure Foundation |  | 60d | 2029-04-27 | 2029-07-19 | 62, 64 | 0d |  |  |  |
| 68 | 13.5.4.2 | Intake Structure Concrete |  | 200d | 2029-07-20 | 2030-04-25 | 67 | 0d |  |  |  |
| 69 | 13.5.4.3 | Intake Structure Gates and Mechanical |  | 90d | 2030-04-26 | 2030-08-29 | 67, 68 | 0d |  |  |  |
| 70 | 13.5.4.4 | I/O Completion and Restoration |  | 60d | 2030-08-30 | 2030-11-21 | 68, 69 | 0d |  |  |  |
| 71 | 13.5.4.5 | Inlet-Outlet Ready for Commissioning | milestone | 0d | 2030-11-21 | 2030-11-21 | 65, 70 | 44d | 0d |  |  |
| 72 | 13.5.4.6 | Inlet-Outlet Startup and Commissioning |  | 90d | 2030-12-26 | 2031-04-30 | 71, 186 | 6d | 0d |  |  |
| 73 | 13.5.4.7 | Inlet-Outlet Completion | milestone | 0d | 2031-04-30 | 2031-04-30 | 72 | 6d |  |  | One Month after Dams Project C1 |
| 74 | 14 | **CONSTRUCTION PACKAGE #2 - MSPG FACILITIES** |  | 2369d | 2022-04-11 | 2031-05-08 |  | 0d |  |  |  |
| 75 | 14.1 | **POWER INTERCONNECTION (CAISO / PG&E DESIGN AND CONSTRUCTION)** |  | 1990d | 2022-04-11 | 2029-11-23 |  | 94d |  |  |  |
| 76 | 14.1.1 | **Prepare & Submit CAISO Package** |  | 265d | 2022-04-11 | 2023-04-14 |  | 94d |  |  |  |
| 77 | 14.1.1.1 | Prepare Pump/Motor Package for Vendors to obtain Data |  | 40d | 2022-04-11 | 2022-06-03 |  | 393d | 0d | start no earlier than 2022-04-11 |  |
| 78 | 14.1.1.2 | Pump Vendors Prepare & Send Data |  | 120d | 2022-06-06 | 2022-11-18 | 77 | 393d | 0d |  |  |
| 79 | 14.1.1.3 | Prepare Hydropower Generator/Turbine Package for Vendors to Obtain Data |  | 40d | 2022-06-22 | 2022-08-16 | 77SS | 94d | 0d | finish no earlier than 2022-08-16 |  |
| 80 | 14.1.1.4 | Generator/Turbine Vendors Prepare & Send Data |  | 68d | 2022-08-17 | 2022-11-18 | 79 | 393d | 0d |  |  |
| 81 | 14.1.1.5 | HC Engineering Team provide info to ZGlobal |  | 30d | 2022-11-21 | 2022-12-30 | 78, 80 | 393d | 0d |  |  |
| 82 | 14.1.1.6 | ZGlobal run models and prepare CAISO package |  | 50d | 2023-01-02 | 2023-03-10 | 81 | 393d | 0d |  |  |
| 83 | 14.1.1.7 | Sites Review CAISO Package & Approve |  | 20d | 2023-03-13 | 2023-04-07 | 82 | 393d | 0d |  |  |
| 84 | 14.1.1.8 | ZGlobal Submit CAISO Package |  | 5d | 2023-04-10 | 2023-04-14 | 83 | 393d | 0d |  |  |

| ID | WBS | Task | Duration | Start | Finish | Predecessors | Total slack | Free slack | Constraint |
| --- | --- | --- | --- | --- | --- | --- | --- | --- | --- |
| 85 | 14.1.2 | **Respond to CAISO** | 587d | 2023-06-01 | 2025-08-29 |  | 94d |  |  |
| 86 | 14.1.2.1 | Scoping Meeting | 22d | 2023-06-01 | 2023-06-30 | 84FS+33d | 393d | 0d |  |
| 87 | 14.1.2.2 | Phase 1 Study | 130d | 2023-07-03 | 2023-12-29 | 86 | 393d | 0d |  |
| 88 | 14.1.2.3 | Phase 1 Results Meeting | 22d | 2024-01-01 | 2024-01-30 | 87 | 393d | 0d |  |
| 89 | 14.1.2.4 | First Finanical Security Posting | 21d | 2024-03-01 | 2024-03-29 | 88FS+22d | 393d | 0d |  |
| 90 | 14.1.2.5 | Phase II Study | 153d | 2024-05-01 | 2024-11-29 | 89FS+22d | 393d | 0d |  |
| 91 | 14.1.2.6 | Phase II Results Meeting | 22d | 2024-12-02 | 2024-12-31 | 90 | 393d | 0d |  |
| 92 | 14.1.2.7 | Transmission Plan Deliverability (Resource Adequacy Process) | 21d | 2025-03-03 | 2025-03-31 | 91FS+43d | 393d | 0d |  |
| 93 | 14.1.2.8 | Second Financial Security Posting | 22d | 2025-05-01 | 2025-05-30 | 92FS+22d | 1563d |  |  |
| 94 | 14.1.2.9 | Draft Impact Analysis Issues | 22d | 2025-05-01 | 2025-05-30 | 92FS+22d | 1498d | 0d |  |
| 95 | 14.1.2.10 | Reassessment Results | 21d | 2025-08-01 | 2025-08-29 | 94FS+44d | 1498d |  |  |
| 96 | 14.1.2.11 | Receive Draft Interconnection Agreement from CAISO | 22d | 2025-05-01 | 2025-05-30 | 92SS+43d | 393d | 0d |  |
| 97 | 14.1.2.12 | Negotiate Interconnection Agreement | 65d | 2025-06-02 | 2025-08-29 | 96 | 393d | 0d |  |
| 98 | 14.1.3 | **PG&E Point of Interconnection Substation** | 1800d | 2023-01-02 | 2029-11-23 |  | 379d |  |  |
| 99 | 14.1.3.1 | **Engineering** | 955d | 2023-01-02 | 2026-08-28 |  | 789d |  |  |
| 100 | 14.1.3.1.1 | Preliminary Design 30% (by HC) | 240d | 2023-01-02 | 2023-12-01 |  | 1853d | 0d | finish no earlier than 2023-12-01 |
| 101 | 14.1.3.1.2 | Class 3 Cost Estimate (by HC) | 100d | 2023-12-04 | 2024-04-19 | 100 | 1853d |  | start no earlier than 2023-12-04 |
| 102 | 14.1.3.1.3 | Establish E&P Agreement with PG&E | 30d | 2024-01-31 | 2024-03-12 | 88 | 1756d | 0d |  |
| 103 | 14.1.3.1.4 | Preliminary Design (30%) | 125d | 2024-03-13 | 2024-09-03 | 102 | 1756d |  | start no earlier than 2022-10-03 |
| 104 | 14.1.3.1.5 | Final 60%, 90%, 100% Design - by PG&E | 260d | 2025-09-01 | 2026-08-28 | 97 | 393d | 0d |  |
| 105 | 14.1.3.2 | **Construction - by PG&E** | 785d | 2026-08-31 | 2029-08-31 |  | 94d |  |  |
| 106 | 14.1.3.2.1 | Procure Equipment | 260d | 2026-08-31 | 2027-08-27 | 104 | 393d | 0d |  |
| 107 | 14.1.3.2.2 | Construction | 525d | 2027-08-30 | 2029-08-31 | 106 | 393d | 0d |  |
| 108 | 14.1.3.3 | **Commissioning** | 60d | 2029-09-03 | 2029-11-23 |  | 94d |  |  |
| 109 | 14.1.3.3.1 | Commission | 60d | 2029-09-03 | 2029-11-23 | 107 | 393d |  |  |

| ID | WBS | Task | Duration | Start | Finish | Predecessors | Baseline start | Baseline finish | Baseline duration | Total slack | Free slack | Constraint | Text1 |
| --- | --- | --- | --- | --- | --- | --- | --- | --- | --- | --- | --- | --- | --- |
| 110 | 3 | **Funks/TRR Pipelines (DSOD Jurisdictional)** | 1750d | 2022-09-01 | 2029-05-16 |  |  |  |  | 516d |  |  |  |
| 111 | 3.3.1 | **Engineering** | 959d | 2022-09-01 | 2026-05-05 |  |  |  |  | 991d |  |  |  |
| 112 | 3.3.1 | Preliminary (30%) | 327d | 2022-09-01 | 2023-12-01 |  | 2022-06-01 | 2023-05-16 | 250d | 1853d | 0d | start no earlier than 2022-09-01 | HC-FTP-100 |
| 113 | 14.2.1.2 | Class 3 Cost Estimate | 100d | 2023-12-04 | 2024-04-19 | 112 |  |  |  | 1853d |  |  |  |
| 114 | 3.3.1 | Final 60% Design | 160d | 2025-01-01 | 2025-08-12 | 5, 7, 8, 6, 10 | 2023-05-17 | 2024-07-09 | 300d | 546d | 0d |  | HC-FTP-110 |
| 115 | 14.2.1.4 | Final 90% Design | 120d | 2025-08-13 | 2026-01-27 | 114 |  |  |  | 546d | 0d |  |  |
| 116 | 4.4.1 | Final 100% Design | 70d | 2026-01-28 | 2026-05-05 | 115 | 2023-06-14 | 2024-10-15 | 350d | 546d | 0d |  | HC-TPL-110 |
| 117 | 3.3.3 | **Construction** | 761d | 2026-05-06 | 2029-04-04 |  |  |  |  | 382d |  |  |  |
| 118 | 3.3.3 | Submittals | 90d | 2026-05-06 | 2026-09-08 | 116 | 2024-11-13 | 2025-02-04 | 60d | 546d | 0d |  | HC-FTP-300 |
| 119 | 3.3.3 | Structures | 330d | 2026-09-09 | 2027-12-14 | 118 | 2025-02-05 | 2026-05-12 | 330d | 826d | 120d |  | HC-FTP-310 |
| 120 | 3.3.3 | Pipelines | 450d | 2026-09-09 | 2028-05-30 | 118 | 2025-02-05 | 2026-08-18 | 400d | 382d | 176d |  | HC-FTP-320 |
| 121 | 3.3.3 | Pipelines in Reservoir | 250d | 2028-02-17 | 2029-01-31 | 118, 152 | 2025-02-05 | 2026-08-18 | 400d | 6d | 0d |  | HC-FTP-320 |
| 122 | 3.3.3 | Testing | 45d | 2029-02-01 | 2029-04-04 | 119, 120, 121 | 2026-08-19 | 2026-10-20 | 45d | 516d | 0d |  | HC-FTP-330 |
| 123 | 3.3.4 | **Commissioning** | 30d | 2029-04-05 | 2029-05-16 |  |  |  |  | 516d |  |  |  |
| 124 | 3.3.4 | Commission | 30d | 2029-04-05 | 2029-05-16 | 122 | 2026-10-21 | 2026-12-01 | 30d | 516d |  |  | HC-FTP-400 |
| 125 | 4 | **Transmission Powerlines** | 2050d | 2022-09-01 | 2030-07-10 |  |  |  |  | 216d |  |  |  |
| 126 | 4.4.1 | **Engineering** | 1270d | 2022-09-01 | 2027-07-14 |  |  |  |  | 921d |  |  |  |
| 127 | 4.4.1 | Preliminary (30%) | 327d | 2022-09-01 | 2023-12-01 |  | 2022-06-01 | 2023-06-13 | 270d | 1839d | 0d | start no earlier than 2022-09-01 | HC-TPL-100 |
| 128 | 14.3.1.2 | Class 3 Cost Estimate | 100d | 2023-12-04 | 2024-04-19 | 127 |  |  |  | 1839d |  |  |  |
| 129 | 5.5.1 | Final 60% Design | 180d | 2026-01-01 | 2026-09-09 | 13, 5, 7, 8, 6, 10 | 2023-06-14 | 2024-10-15 | 350d | 51d | 0d |  | HC-FRV-110 |
| 130 | 14.3.1.4 | Final 90% Design | 150d | 2026-09-10 | 2027-04-07 | 129 |  |  |  | 51d | 0d |  |  |
| 131 | 4.4.1 | Final 100% Design | 70d | 2027-04-08 | 2027-07-14 | 130 | 2023-06-14 | 2024-10-15 | 350d | 51d | 0d |  | HC-TPL-110 |
| 132 | 4.4.3 | **Construction** | 750d | 2027-07-15 | 2030-05-29 |  |  |  |  | 6d |  |  |  |
| 133 | 4.4.3 | Submittals | 60d | 2027-07-15 | 2027-10-06 | 131, 162 | 2025-02-19 | 2025-05-13 | 60d | 51d | 0d |  | HC-TPL-300 |
| 134 | 4.4.3 | Procurement | 300d | 2027-10-07 | 2028-11-29 | 133 | 2025-05-14 | 2026-07-07 | 300d | 51d | 0d |  | HC-TPL-310 |
| 135 | 4.4.3 | Towers/Powerlines to POI | 175d | 2028-11-30 | 2029-08-01 | 133, 134 | 2026-07-08 | 2027-08-31 | 300d | 176d | 170d |  | HC-TPL-320 |
| 136 | 4.4.3 | Towers/Powerlines Funks/TRR | 300d | 2029-02-01 | 2030-03-27 | 120SS+250d, 134, 121SS+250d | 2026-08-19 | 2027-11-23 | 330d | 6d | 0d |  | HC-TPL-330 |
| 137 | 4.4.3 | Testing | 45d | 2030-03-28 | 2030-05-29 | 134, 135, 136, 109 | 2027-11-24 | 2028-01-25 | 45d | 6d | 0d |  | HC-TPL-340 |

| ID | WBS | Task | Duration | Start | Finish | Predecessors | Baseline start | Baseline finish | Baseline duration | Total slack | Free slack | Constraint | Text1 |
| --- | --- | --- | --- | --- | --- | --- | --- | --- | --- | --- | --- | --- | --- |
| 138 | 4.4.4 | **Commissioning** | 30d | 2030-05-30 | 2030-07-10 |  |  |  |  | 6d |  |  |  |
| 139 | 4.4.4 | Commission | 30d | 2030-05-30 | 2030-07-10 | 137 | 2028-01-26 | 2028-03-07 | 30d | 6d | 0d |  | HC-TPL-400 |
| 140 | 5 | **Funks Reservoir** | 2266d | 2022-09-01 | 2031-05-08 |  |  |  |  | 0d |  |  |  |
| 141 | 5.5.1 | **Engineering** | 1220d | 2022-09-01 | 2027-05-05 |  |  |  |  | 876d |  |  |  |
| 142 | 5.5.1 | Preliminary Design (30%) | 327d | 2022-09-01 | 2023-12-01 |  | 2022-06-01 | 2023-06-13 | 270d | 1839d | 0d | start no earlier than 2022-09-01 | HC-FRV-100 |
| 143 | 14.4.1.2 | Class 3 Cost Estimate | 100d | 2023-12-04 | 2024-04-19 | 142 |  |  |  | 1839d |  |  |  |
| 144 | 5.5.1 | Final 60% Design | 130d | 2026-01-01 | 2026-07-01 | 10, 13 | 2023-06-14 | 2024-10-15 | 350d | 6d | 0d |  | HC-FRV-110 |
| 145 | 14.4.1.4 | Final 90% Design | 130d | 2026-07-02 | 2026-12-30 | 144 |  |  |  | 6d | 0d |  |  |
| 146 | 14.4.1.5 | Final 100% Design | 90d | 2026-12-31 | 2027-05-05 | 145 |  |  |  | 6d | 0d |  |  |
| 147 | 5.5.3 | **Construction** | 1046d | 2027-05-06 | 2031-05-08 |  |  |  |  | 0d |  |  |  |
| 148 | 5.5.3 | Submittals | 120d | 2027-05-06 | 2027-10-20 | 146 | 2025-02-19 | 2025-08-05 | 120d | 6d | 0d |  | HC-FRV-300 |
| 149 | 5.5.3 | Haulroads | 200d | 2027-10-21 | 2028-07-26 | 148 | 2025-08-06 | 2026-05-12 | 200d | 726d |  |  | HC-FRV-310 |
| 150 | 5.5.3 | Initial Sediment Removal | 400d | 2027-10-21 | 2029-05-02 | 148 | 2025-08-06 | 2026-07-21 | 250d | 526d |  |  | HC-FRV-320 |
| 151 | 5.5.3 | PGP Cofferdams (build) | 85d | 2027-10-21 | 2028-02-16 | 148 | 2026-07-22 | 2027-07-06 | 250d | 51d | 0d | start no earlier than 2025-12-01 | HC-FRV-330 |
| 152 | 5.5.3 | Pipeline Cofferdams (build) | 85d | 2027-10-21 | 2028-02-16 | 148 | 2026-07-22 | 2027-07-06 | 250d | 6d | 0d | start no earlier than 2026-12-01 | HC-FRV-330 |
| 153 | 14.4.2.6 | Final Sediment Removal (After I/O and Golden Gate Dam nearly complete) | 120d | 2030-11-22 | 2031-05-08 | 70 |  |  |  | 0d |  |  |  |
| 154 | 5.5.4 | **Commissioning** | 30d | 2028-02-17 | 2028-03-29 |  |  |  |  | 811d |  |  |  |
| 155 | 5.5.4 | Commission | 30d | 2028-02-17 | 2028-03-29 | 152 | 2027-09-29 | 2027-11-09 | 30d | 811d |  |  | HC-FRV-400 |
| 156 | 6 | **Funks Pumping Generating Plant** | 2260d | 2022-09-01 | 2031-04-30 |  |  |  |  | 6d |  |  |  |
| 157 | 6.6.1 | **Engineering** | 1150d | 2022-09-01 | 2027-01-27 |  |  |  |  | 921d |  |  |  |
| 158 | 6.6.1 | Preliminary (30%) | 327d | 2022-09-01 | 2023-12-01 |  | 2022-06-01 | 2023-06-13 | 270d | 1839d | 0d | start no earlier than 2022-09-01 | HC-FPG-100 |
| 159 | 14.5.1.2 | Class 3 Cost Estimate | 100d | 2023-12-04 | 2024-04-19 | 158 |  |  |  | 1839d |  |  |  |
| 160 | 5.5.1 | Final 60% Design | 180d | 2025-07-17 | 2026-03-25 | 13FS-120d, 5, 7, 8, 6, 10 | 2023-06-14 | 2024-10-15 | 350d | 171d | 0d |  | HC-FRV-110 |
| 161 | 14.5.1.4 | Final 90% Design | 150d | 2026-03-26 | 2026-10-21 | 160 |  |  |  | 171d | 0d |  |  |
| 162 | 4.4.1 | Final 100% Design | 70d | 2026-10-22 | 2027-01-27 | 161 | 2023-06-14 | 2024-10-15 | 350d | 171d | 0d |  | HC-TPL-110 |

| ID | WBS | Task | Duration | Start | Finish | Predecessors | Baseline start | Baseline finish | Baseline duration | Total slack | Free slack | Constraint | Text1 |
| --- | --- | --- | --- | --- | --- | --- | --- | --- | --- | --- | --- | --- | --- |
| 163 | 6.6.3 | **Construction** | 1080d | 2027-01-28 | 2031-03-19 |  |  |  |  | 36d |  |  |  |
| 164 | 6.6.3 | Submittals | 120d | 2027-01-28 | 2027-07-14 | 162 | 2025-02-19 | 2025-08-05 | 120d | 206d | 0d |  | HC-FPG-300 |
| 165 | 6.6.3 | Large Equipment Procurement | 350d | 2027-07-15 | 2028-11-15 | 164 | 2025-08-06 | 2026-12-08 | 350d | 646d |  |  | HC-FPG-310 |
| 166 | 9.9.3 | Pump Generating Plant Structure | 700d | 2028-02-17 | 2030-10-23 | 164, 151 | 2026-05-27 | 2027-07-20 | 300d | 51d | 45d |  | HC-SUB-320 |
| 167 | 14.5.2.4 | Turbine Structure | 330d | 2027-10-07 | 2029-01-10 | 164FS+60d |  |  |  | 516d | 510d |  |  |
| 168 | 14.5.2.5 | Energy Dissipation Valve Structure | 265d | 2027-12-30 | 2029-01-03 | 164FS+120d |  |  |  | 521d | 515d |  |  |
| 169 | 14.5.2.6 | Electrical Building | 265d | 2028-03-23 | 2029-03-28 | 164FS+180d |  |  |  | 461d | 455d |  |  |
| 170 | 14.5.2.7 | Site Electrical and PGP Sitework | 450d | 2027-07-15 | 2029-04-04 | 164 |  |  |  | 456d | 450d |  |  |
| 171 | 6.6.3 | Testing | 60d | 2030-12-26 | 2031-03-19 | 170, 166, 167, 169, 168, 137, 186 | 2028-04-12 | 2028-07-04 | 60d | 6d | 0d |  | HC-FPG-330 |
| 172 | 6.6.4 | **Commissioning** | 30d | 2031-03-20 | 2031-04-30 |  |  |  |  | 6d |  |  |  |
| 173 | 6.6.4 | Commission | 30d | 2031-03-20 | 2031-04-30 | 171 | 2028-07-05 | 2028-08-15 | 30d | 6d |  |  | HC-FPG-400 |
| 174 | 14.6 | **Funks Substation** | 2170d | 2022-09-01 | 2030-12-25 |  |  |  |  | 96d |  |  |  |
| 175 | 14.6.1 | **Engineering (Excludes PG&E]** | 1139d | 2022-09-01 | 2027-01-12 |  |  |  |  | 1126d |  |  |  |
| 176 | 14.6.1.1 | Design 30% | 300d | 2022-09-01 | 2023-10-25 | 84FF+30d |  |  |  | 1926d | 0d | start no earlier than 2022-09-01 |  |
| 177 | 14.6.1.2 | Class 3 Cost Estimate | 40d | 2023-10-26 | 2023-12-20 | 176 |  |  |  | 1926d |  |  |  |
| 178 | 14.6.1.3 | Final 60% Design | 220d | 2025-01-01 | 2025-11-04 | 10, 5, 6, 7, 8 |  |  |  | 517d | 0d |  |  |
| 179 | 14.6.1.4 | Final 90% Design | 180d | 2025-11-05 | 2026-07-14 | 178 |  |  |  | 517d | 0d |  |  |
| 180 | 14.6.1.5 | Final 100% Design | 130d | 2026-07-15 | 2027-01-12 | 179 |  |  |  | 517d | 0d |  |  |
| 181 | 14.6.2 | **Construction** | 400d | 2027-01-13 | 2028-07-25 |  |  |  |  | 517d | 511d |  |  |
| 182 | 9.9.3 | Submittals | 100d | 2027-01-13 | 2027-06-01 | 180 | 2025-12-10 | 2026-05-26 | 120d | 517d | 0d |  | HC-SUB-300 |
| 183 | 14.6.2.2 | Earthwork/Pad Prep | 150d | 2027-06-02 | 2027-12-28 | 182 |  |  |  | 517d | 0d |  |  |
| 184 | 9.9.3 | Large Equipment Procurement | 150d | 2027-06-02 | 2027-12-28 | 182 | 2026-05-27 | 2027-05-11 | 250d | 667d |  |  | HC-SUB-310 |
| 185 | 14.6.2.4 | Breaker Substation | 150d | 2027-12-29 | 2028-07-25 | 183 |  |  |  | 517d |  |  |  |
| 186 | 14.6.3 | Commissioning | 120d | 2030-07-11 | 2030-12-25 | 181, 139 |  |  |  | 6d | 0d |  |  |

| ID | WBS | Task | Type | Duration | Start | Finish | Predecessors | Baseline start | Baseline finish | Baseline duration | Total slack | Free slack | Constraint | Text1 |
| --- | --- | --- | --- | --- | --- | --- | --- | --- | --- | --- | --- | --- | --- | --- |
| 187 | 7 | **TRR West Reservoir** |  | 2010d | 2022-09-01 | 2030-05-15 |  |  |  |  | 256d |  |  |  |
| 188 | 7.7.1 | **Engineering** |  | 1250d | 2022-09-01 | 2027-06-16 |  |  |  |  | 1016d |  |  |  |
| 189 | 7.7.1 | Preliminary (30%) |  | 327d | 2022-09-01 | 2023-12-01 |  | 2022-06-01 | 2023-06-13 | 270d | 1839d | 0d | start no earlier than 2022-09-01 | HC-TER-100 |
| 190 | 14.7.1.2 | Class 3 Cost Estimate |  | 100d | 2023-12-04 | 2024-04-19 | 189 |  |  |  | 1839d |  |  |  |
| 191 | 14.7.1.3 | Final 60% Design |  | 130d | 2026-01-01 | 2026-07-01 | 13, 10 |  |  |  | 256d | 0d | finish no earlier than 2026-07-01 |  |
| 192 | 14.7.1.4 | Final 90% Design |  | 150d | 2026-07-02 | 2027-01-27 | 191 |  |  |  | 256d | 0d |  |  |
| 193 | 7.7.1 | Final 100% Design |  | 100d | 2027-01-28 | 2027-06-16 | 192 | 2023-06-14 | 2024-10-15 | 350d | 256d | 0d |  | HC-TER-110 |
| 194 | 7.7.3 | **Construction** |  | 730d | 2027-06-17 | 2030-04-03 |  |  |  |  | 256d |  |  |  |
| 195 | 7.7.3 | Submittals |  | 120d | 2027-06-17 | 2027-12-01 | 193 | 2025-02-19 | 2025-08-05 | 120d | 256d | 0d |  | HC-TER-300 |
| 196 | 7.7.3 | Haulroads |  | 200d | 2027-12-02 | 2028-09-06 | 195 | 2025-08-06 | 2026-05-12 | 200d | 256d | 0d |  | HC-TER-310 |
| 197 | 7.7.3 | Earthwork/Structures |  | 300d | 2028-09-07 | 2029-10-31 | 196 | 2026-07-22 | 2027-09-14 | 300d | 256d | 0d |  | HC-TER-330 |
| 198 | 7.7.3 | Subgrade and Liner |  | 200d | 2029-04-05 | 2030-01-09 | 197FS-1200h | 2027-02-17 | 2027-11-23 | 200d | 256d | 0d |  | HC-TER-340 |
| 199 | 7.7.3 | Testing |  | 60d | 2030-01-10 | 2030-04-03 | 197, 198 | 2027-11-24 | 2028-02-15 | 60d | 256d | 0d |  | HC-TER-350 |
| 200 | 7.7.4 | **Commissioning** |  | 30d | 2030-04-04 | 2030-05-15 |  |  |  |  | 256d |  |  |  |
| 201 | 7.7.4 | Commission |  | 30d | 2030-04-04 | 2030-05-15 | 199 | 2028-02-16 | 2028-03-28 | 30d | 256d |  |  | HC-TER-400 |
| 202 | 8 | **TRR West Pumping Generating Plant** |  | 2260d | 2022-09-01 | 2031-04-30 |  |  |  |  | 0d |  |  |  |
| 203 | 8.8.1 | **Engineering** |  | 1150d | 2022-09-01 | 2027-01-27 |  |  |  |  | 0d |  |  |  |
| 204 | 8.8.1 | Preliminary (30%) | manual | 327d | 2022-09-01 | 2023-12-01 |  | 2022-06-01 | 2023-06-13 | 270d |  |  | start no earlier than 2022-09-01 | HC-TPG-100 |
| 205 | 14.8.1.2 | Class 3 Cost Estimate |  | 100d | 2023-12-04 | 2024-04-19 | 204 |  |  |  | 1839d |  |  |  |
| 206 | 5.5.1 | Final 60% Design |  | 180d | 2025-07-17 | 2026-03-25 | 13FS-120d, 5, 7, 8, 6, 10 | 2023-06-14 | 2024-10-15 | 350d | 206d | 0d |  | HC-FRV-110 |
| 207 | 14.8.1.4 | Final 90% Design |  | 150d | 2026-03-26 | 2026-10-21 | 206 |  |  |  | 206d | 0d |  |  |
| 208 | 4.4.1 | Final 100% Design |  | 70d | 2026-10-22 | 2027-01-27 | 207 | 2023-06-14 | 2024-10-15 | 350d | 206d | 20d |  | HC-TPL-110 |
| 209 | 8.8.3 | **Construction** |  | 1060d | 2027-02-25 | 2031-03-19 |  |  |  |  | 36d |  |  |  |
| 210 | 8.8.3 | Submittals |  | 120d | 2027-02-25 | 2027-08-11 | 208, 238 | 2025-02-19 | 2025-08-05 | 120d | 186d | 0d |  | HC-TPG-300 |
| 211 | 8.8.3 | Large Equipment Procurement |  | 355d | 2027-08-12 | 2028-12-20 | 210 | 2025-08-06 | 2026-12-15 | 355d | 621d |  | start no earlier than 2022-10-10 | HC-TPG-310 |
| 212 | 9.9.3 | Pump Generating Plant Structure |  | 700d | 2027-08-12 | 2030-04-17 | 210 | 2026-05-27 | 2027-07-20 | 300d | 186d | 180d |  | HC-SUB-320 |
| 213 | 14.8.2.4 | Turbine Structure |  | 330d | 2027-11-04 | 2029-02-07 | 210FS+60d |  |  |  | 496d | 490d |  |  |
| 214 | 14.8.2.5 | Energy Dissipation Valve Structure |  | 265d | 2028-01-27 | 2029-01-31 | 210FS+120d |  |  |  | 501d | 495d |  |  |
| 215 | 14.8.2.6 | Electrical Building |  | 265d | 2028-04-20 | 2029-04-25 | 210FS+180d |  |  |  | 441d | 435d |  |  |
| 216 | 14.8.2.7 | Site Electrical and PGP Sitework |  | 450d | 2027-08-12 | 2029-05-02 | 210 |  |  |  | 436d | 430d |  |  |
| 217 | 8.8.3 | Testing |  | 60d | 2030-12-26 | 2031-03-19 | 137, 215, 212, 213, 214, 216, 231 | 2028-04-12 | 2028-07-04 | 60d | 6d | 0d |  | HC-TPG-330 |

| ID | WBS | Task | Duration | Start | Finish | Predecessors | Baseline start | Baseline finish | Baseline duration | Total slack | Free slack | Constraint | Text1 |
| --- | --- | --- | --- | --- | --- | --- | --- | --- | --- | --- | --- | --- | --- |
| 218 | 8.8.4 | **Commissioning** | 30d | 2031-03-20 | 2031-04-30 |  |  |  |  | 6d |  |  |  |
| 219 | 8.8.4 | Commission | 30d | 2031-03-20 | 2031-04-30 | 217 | 2028-07-05 | 2028-08-15 | 30d | 6d |  |  | HC-TPG-400 |
| 220 | 9 | **TRR West Substation** | 2170d | 2022-09-01 | 2030-12-25 |  |  |  |  | 96d |  |  |  |
| 221 | 9.9.1 | **Engineering [excludes PG&E]** | 1139d | 2022-09-01 | 2027-01-12 |  |  |  |  | 936d |  |  |  |
| 222 | 9.9.1 | Preliminary (30%) | 300d | 2022-09-01 | 2023-10-25 | 84FF+30d | 2022-06-01 | 2023-06-13 | 270d | 1926d | 0d | start no earlier than 2022-09-01 | HC-SUB-100 |
| 223 | 14.9.1.2 | Class 3 Cost Estimate | 40d | 2023-10-26 | 2023-12-20 | 222 |  |  |  | 1926d |  |  |  |
| 224 | 9.9.1 | Design (60%, 90%, 100%) | 530d | 2025-01-01 | 2027-01-12 | 10, 5, 6, 7, 8 | 2023-06-14 | 2024-10-15 | 350d | 327d | 0d |  | HC-SUB-110 |
| 225 | 9.9.3 | **Construction** | 500d | 2027-05-19 | 2029-04-17 |  |  |  |  | 327d | 321d |  |  |
| 226 | 9.9.3 | Submittals | 100d | 2027-05-19 | 2027-10-05 | 224FS+90d | 2025-12-10 | 2026-05-26 | 120d | 327d | 0d |  | HC-SUB-300 |
| 227 | 14.9.2.2 | Earthwork/Pad Prep | 150d | 2027-10-06 | 2028-05-02 | 226 |  |  |  | 577d |  |  |  |
| 228 | 9.9.3 | Large Equipment Procurement | 150d | 2027-10-06 | 2028-05-02 | 226 | 2026-05-27 | 2027-05-11 | 250d | 327d | 0d |  | HC-SUB-310 |
| 229 | 9.9.3 | Structures | 250d | 2028-05-03 | 2029-04-17 | 228 | 2026-05-27 | 2027-07-20 | 300d | 327d |  |  | HC-SUB-320 |
| 230 | 9.9.4 | **Commissioning** | 120d | 2030-07-11 | 2030-12-25 | 225 |  |  |  | 6d |  |  |  |
| 231 | 9.9.4 | Commission | 120d | 2030-07-11 | 2030-12-25 | 225, 139 | 2028-05-31 | 2028-07-11 | 30d | 6d | 0d |  | HC-SUB-400 |
| 232 | 1 | **CONSTRUCTION PACKAGE #5 - DUNNIGAN PIPELINE (ALT 1)** | 1645d | 2022-09-01 | 2028-12-20 |  |  |  |  | 621d |  |  |  |
| 233 | 1.1.1 | **Engineering** | 1170d | 2022-09-01 | 2027-02-24 |  |  |  |  | 1056d |  |  |  |
| 234 | 1.1.1 | Preliminary (30%) | 327d | 2022-09-01 | 2023-12-01 |  | 2022-06-01 | 2023-03-07 | 200d | 1839d | 0d | start no earlier than 2022-09-01 | HC-DP1-100 |
| 235 | 15.1.2 | Class 3 Cost Estimate | 100d | 2023-12-04 | 2024-04-19 | 234 |  |  |  | 1839d |  |  |  |
| 236 | 5.5.1 | Final 60% Design | 130d | 2026-01-01 | 2026-07-01 | 13, 5, 7, 8, 6, 10 | 2023-06-14 | 2024-10-15 | 350d | 186d | 0d |  | HC-FRV-110 |
| 237 | 15.1.4 | Final 90% Design | 100d | 2026-07-02 | 2026-11-18 | 236 |  |  |  | 186d | 0d |  |  |
| 238 | 4.4.1 | Final 100% Design | 70d | 2026-11-19 | 2027-02-24 | 237 | 2023-06-14 | 2024-10-15 | 350d | 186d | 0d |  | HC-TPL-110 |
| 239 | 1.1.2 | **Bid and Award** | 90d | 2027-02-25 | 2027-06-30 |  |  |  |  | 621d |  |  |  |
| 240 | 1.1.2 | Bid and Award | 90d | 2027-02-25 | 2027-06-30 | 238 | 2024-02-21 | 2024-06-25 | 90d | 621d | 0d |  | HC-DP1-200 |
| 241 | 1.1.3 | **Construction** | 360d | 2027-07-01 | 2028-11-15 |  |  |  |  | 621d |  |  |  |
| 242 | 1.1.3 | Submittals | 60d | 2027-07-01 | 2027-09-22 | 240 | 2024-06-26 | 2024-09-17 | 60d | 621d | 0d |  | HC-DP1-300 |
| 243 | 1.1.3 | TCC Intake Structure | 160d | 2027-09-23 | 2028-05-03 | 242 | 2024-09-18 | 2025-08-19 | 240d | 646d | 0d |  | HC-DP1-310 |
| 244 | 15.3.3 | CBD Discharge Structure | 140d | 2028-05-04 | 2028-11-15 | 243 |  |  |  | 646d |  |  |  |
| 245 | 1.1.3 | Pipeline | 250d | 2027-09-23 | 2028-09-06 | 242 | 2024-09-18 | 2025-09-02 | 250d | 621d | 0d |  | HC-DP1-320 |
| 246 | 1.1.3 | Testing | 45d | 2028-09-07 | 2028-11-08 | 243, 245 | 2025-09-03 | 2025-11-04 | 45d | 621d | 0d |  | HC-DP1-330 |

| ID | WBS | Task | Duration | Start | Finish | Predecessors | Baseline start | Baseline finish | Baseline duration | Total slack | Free slack | Constraint | Text1 |
| --- | --- | --- | --- | --- | --- | --- | --- | --- | --- | --- | --- | --- | --- |
| 247 | 1.1.4 | **Commissioning** | 30d | 2028-11-09 | 2028-12-20 |  |  |  |  | 621d |  |  |  |
| 248 | 1.1.4 | Commission | 30d | 2028-11-09 | 2028-12-20 | 246 | 2025-11-05 | 2025-12-16 | 30d | 621d |  |  | HC-DP1-400 |
| 249 | 10 | **CONSTRUCTION PACKAGE #6 - RED BLUFF PUMPING PLANT (BY TCCA)** | 1130d | 2025-01-06 | 2029-05-04 |  |  |  |  | 524d |  |  |  |
| 250 | 10.10.1 | **Engineering** | 290d | 2025-01-06 | 2026-02-13 |  |  |  |  | 524d |  |  |  |
| 251 | 10.10.1 | Preliminary (30%) | 90d | 2025-01-06 | 2025-05-09 |  | 2023-01-02 | 2023-05-05 | 90d | 524d | 0d | start no earlier than 2025-01-06 | HC-RBP-100 |
| 252 | 10.10.1 | Final (60%, 90%, 100%) | 200d | 2025-05-12 | 2026-02-13 | 251 | 2023-05-08 | 2023-10-20 | 120d | 524d | 0d |  | HC-RBP-110 |
| 253 | 10.10.2 | **Bid and Award** | 90d | 2026-02-16 | 2026-06-19 |  |  |  |  | 524d |  |  |  |
| 254 | 10.10.2 | Bid and Award | 90d | 2026-02-16 | 2026-06-19 | 252 | 2024-09-30 | 2025-01-31 | 90d | 524d | 0d | start no earlier than 2024-09-30 | HC-RBP-200 |
| 255 | 10.10.3 | **Construction** | 720d | 2026-06-22 | 2029-03-23 |  |  |  |  | 524d |  |  |  |
| 256 | 10.10.3 | Submittals | 120d | 2026-06-22 | 2026-12-04 | 254 | 2025-02-03 | 2025-07-18 | 120d | 524d | 0d |  | HC-RBP-300 |
| 257 | 10.10.3 | Pump Procurement | 18mo | 2026-12-07 | 2028-04-21 | 256 | 2025-07-21 | 2026-04-24 | 200d | 524d | 0d |  | HC-RBP-310 |
| 258 | 10.10.3 | Mechanical/Electrical | 180d | 2028-04-24 | 2028-12-29 | 257 | 2026-04-27 | 2027-01-01 | 180d | 524d | 0d |  | HC-RBP-320 |
| 259 | 10.10.3 | Testing | 60d | 2029-01-01 | 2029-03-23 | 258 | 2027-01-04 | 2027-03-26 | 60d | 524d | 0d |  | HC-RBP-330 |
| 260 | 10.10.4 | **Commissioning** | 30d | 2029-03-26 | 2029-05-04 |  |  |  |  | 524d |  |  |  |
| 261 | 10.10.4 | Commission | 30d | 2029-03-26 | 2029-05-04 | 259 | 2027-03-29 | 2027-05-07 | 30d | 524d |  |  | HC-RBP-400 |
| 262 | 11 | **CONSTRUCTION PACKAGE #7 - GCID IMPROVMENTS (BY GCID)** | 1220d | 2025-01-06 | 2029-09-07 |  |  |  |  | 434d |  |  |  |
| 263 | 11.11.1 | **Engineering** | 440d | 2025-01-06 | 2026-09-11 |  |  |  |  | 434d |  |  |  |
| 264 | 11.11.1 | Preliminary (30%) | 120d | 2025-01-06 | 2025-06-20 |  | 2022-06-01 | 2023-06-13 | 270d | 434d | 0d | start no earlier than 2025-01-06 | HC-GCI-100 |
| 265 | 11.11.1 | Final (60%, 90%, 100%) | 320d | 2025-06-23 | 2026-09-11 | 264 | 2023-06-14 | 2024-10-15 | 350d | 434d | 0d |  | HC-GCI-110 |
| 266 | 11.11.2 | **Bid and Award** | 90d | 2026-09-14 | 2027-01-15 |  |  |  |  | 434d |  |  |  |
| 267 | 11.11.2 | Bid and Award | 90d | 2026-09-14 | 2027-01-15 | 265 | 2024-10-16 | 2025-02-18 | 90d | 434d | 0d |  | HC-GCI-200 |
| 268 | 11.11.3 | **Construction** | 660d | 2027-01-18 | 2029-07-27 |  |  |  |  | 434d |  |  |  |
| 269 | 11.11.3 | Submittals | 120d | 2027-01-18 | 2027-07-02 | 267 | 2025-02-19 | 2025-08-05 | 120d | 434d | 0d |  | HC-GCI-300 |
| 270 | 11.11.3 | Structures | 24mo | 2027-07-05 | 2029-05-04 | 269 | 2025-08-06 | 2027-07-06 | 500d | 524d |  |  | HC-GCI-310 |
| 271 | 11.11.3 | Earthwork | 24mo | 2027-07-05 | 2029-05-04 | 269 | 2025-08-06 | 2027-07-06 | 500d | 434d | 0d |  | HC-GCI-320 |
| 272 | 11.11.3 | Testing | 60d | 2029-05-07 | 2029-07-27 | 271 | 2027-07-07 | 2027-09-28 | 60d | 434d | 0d |  | HC-GCI-330 |

| ID | WBS | Task | Duration | Start | Finish | Predecessors | Baseline start | Baseline finish | Baseline duration | Total slack | Text1 |
| --- | --- | --- | --- | --- | --- | --- | --- | --- | --- | --- | --- |
| 273 | 11.11.4 | **Commissioning** | 30d | 2029-07-30 | 2029-09-07 |  |  |  |  | 434d |  |
| 274 | 11.11.4 | Commission | 30d | 2029-07-30 | 2029-09-07 | 272 | 2027-09-29 | 2027-11-09 | 30d | 434d | HC-GCI-400 |
